# 製品開発プロジェクト-FIELD

Schedule from MS Project, 2006-02-01 to 2006-03-06, costs in ¥.
繝槭う繧ｯ繝ｭ繧｢繝励Μ譬ｪ蠑丈ｼ夂､ｾ

## Calendars

- 標準: Mon-Fri 08:00-12:00, 13:00-17:00; Sat-Sun off.

## Resources

| Resource | Group | Rate |
| --- | --- | --- |
| 高橋 | 製品グループ | 2000 |
| 渡辺 | 製品グループ | 3000 |
| 伊藤 | モジュー21開発G | 2000 |
| 松本 | モジュール1開発G | 2500 |

## Schedule

| ID | WBS | Task | Type | Duration | Start | Finish | Predecessors | Baseline start | Baseline finish | Baseline duration | Total slack | Free slack | Deadline | Resources | Work | Cost | Baseline cost |
| --- | --- | --- | --- | --- | --- | --- | --- | --- | --- | --- | --- | --- | --- | --- | --- | --- | --- |
| 1 | 1 | 契約締結 | milestone | 0d | 2006-02-01 | 2006-02-01 |  | 2006-02-01 | 2006-02-01 | 0d | 2d | 0d |  |  |  |  |  |
| 2 | 2 | 納品 | milestone | 0d | 2006-03-06 | 2006-03-06 | 14 | 2006-03-06 | 2006-03-06 | 0d | 2d |  | 2006-03-08 |  |  |  |  |
| 4 | 3 | 要件定義 |  | 2d | 2006-02-01 | 2006-02-02 | 1 | 2006-02-01 | 2006-02-02 | 2d | 2d | 0d |  | 高橋 | 16h | 32,000 | 32,000 |
| 5 | 4 | 基本設計 |  | 3d | 2006-02-03 | 2006-02-07 | 4 | 2006-02-03 | 2006-02-07 | 3d | 2d | 0d |  | 高橋 | 24h | 48,000 | 48,000 |
| 6 | 5 | **詳細設計** |  | 8d | 2006-02-08 | 2006-02-17 | 5 | 2006-02-08 | 2006-02-17 | 8d | 2d |  |  |  | 96h | 208,000 | 208,000 |
| 7 | 5.1 | 詳細設計【モジュール2】 |  | 4d | 2006-02-08 | 2006-02-13 |  | 2006-02-08 | 2006-02-13 | 4d | 2d | 0d |  | 伊藤 | 32h | 64,000 | 64,000 |
| 8 | 5.2 | 詳細設計【モジュール1】 |  | 4d | 2006-02-08 | 2006-02-13 |  | 2006-02-08 | 2006-02-13 | 4d | 2d | 0d |  | 松本 | 32h | 80,000 | 80,000 |
| 9 | 5.3 | モジュール統合設計 |  | 4d | 2006-02-14 | 2006-02-17 | 8, 7 | 2006-02-14 | 2006-02-17 | 4d | 2d | 0d |  | 高橋 | 32h | 64,000 | 64,000 |
| 10 | 6 | **テスト** |  | 11d | 2006-02-16 | 2006-03-02 |  | 2006-02-16 | 2006-03-02 | 11d | 2d |  |  |  | 128h | 316,000 | 316,000 |
| 11 | 6.1 | テスト【モジュール1】 |  | 5d | 2006-02-16 | 2006-02-22 | 9FS-2d | 2006-02-16 | 2006-02-22 | 5d | 4d | 2d |  | 伊藤 | 40h | 80,000 | 80,000 |
| 12 | 6.2 | テスト【モジュール2】 |  | 7d | 2006-02-16 | 2006-02-24 | 9FS-2d | 2006-02-16 | 2006-02-24 | 7d | 2d | 0d |  | 松本 | 56h | 140,000 | 140,000 |
| 13 | 6.3 | モジュール統合テスト |  | 4d | 2006-02-27 | 2006-03-02 | 12, 11 | 2006-02-27 | 2006-03-02 | 4d | 2d | 0d |  | 渡辺 | 32h | 96,000 | 96,000 |
| 14 | 7 | 納品準備 |  | 4d | 2006-03-01 | 2006-03-06 | 13FS-2d | 2006-03-01 | 2006-03-06 | 4d | 3d | 0d |  | 高橋 | 32h | 64,000 | 64,000 |
