# 業者の評価と整理統合

Schedule from MS Project, 2005-06-01 to 2006-02-10.
企業は高品質のサービスを魅力的な価格で提供する、実績のある業者を好みます。効率と品質を保証するため、企業は定期的に取引業者の見直しを行います。この結果、多くの場合企業は整理統合されたより小さなグループの中から毎回ほぼ同じ業者を選ぶことになります。一般的に、主要取引業者に選ばれる業者は、割引価格でサービスを提供しています。このテンプレートでは、このような評価および整理統合プロセスに関わる一般的な活動を扱います。

## Calendars

- Standard: Mon-Fri 08:00-12:00, 13:00-17:00; Sat-Sun off.

## Resources

| Resource |
| --- |
| マネジメント |
| 製品技術 |
| プロジェクトマネージャ |
| マーケティング |
| プロセスエンジニア |
| 生産技術 |
| 安全 |
| 法務 |
| 経理 |
| 顧客 |
| 購買 |
| 情報システム |

## Schedule

| ID | WBS | Task | Type | Duration | Start | Finish | Predecessors | Total slack | Resources | Work |
| --- | --- | --- | --- | --- | --- | --- | --- | --- | --- | --- |
| 1 | 1 | **予備調査の実施** |  | 15d | 2005-06-01 | 2005-06-21 |  | 0d |  | 168h |
| 2 | 1.1 | 予備調査についてリソースを割り当てる |  | 1d | 2005-06-01 | 2005-06-01 |  | 0d | 購買 | 8h |
| 3 | 1.2 | 予備調査の計画を作成する |  | 1w | 2005-06-01 | 2005-06-07 | 2SS | 0d | 購買 | 40h |
| 4 | 1.3 | 分析/業者レビューの範囲を特定する |  | 2w | 2005-06-08 | 2005-06-21 | 3 | 0d | 購買 | 80h |
| 5 | 1.4 | 候補業者および選択肢を分析する |  | 1w | 2005-06-01 | 2005-06-07 | 3SS | 177.5d | 購買 | 40h |
| 6 | 1.5 | 予備調査完了 | milestone | 0d | 2005-06-21 | 2005-06-21 | 2, 3, 4 | 0d |  |  |
| 7 | 2 | **業者要件分析の実施** |  | 20d | 2005-06-22 | 2005-07-19 |  | 0d |  | 840h |
| 8 | 2.1 | **整理統合する業者群を特定する** |  | 10d | 2005-06-22 | 2005-07-05 |  | 0d |  | 160h |
| 9 | 2.1.1 | 購買およびアウトソーシングに関する統計情報を分析する |  | 1w | 2005-06-22 | 2005-06-28 | 6 | 0d | 購買 | 40h |
| 10 | 2.1.2 | 業者の割引条件およびサービス範囲を分析する |  | 1w | 2005-06-22 | 2005-06-28 | 9SS | 0d | 購買 | 40h |
| 11 | 2.1.3 | アウトソーシングする分野に優先順位を付ける |  | 1w | 2005-06-29 | 2005-07-05 | 10 | 0d | 購買 | 40h |
| 12 | 2.1.4 | レビュー対象の業者の一覧をまとめる |  | 1w | 2005-06-29 | 2005-07-05 | 11SS | 0d | 購買 | 40h |
| 13 | 2.1.5 | 業者群の特定完了 | milestone | 0d | 2005-07-05 | 2005-07-05 | 12, 11 | 0d |  |  |
| 14 | 2.2 | **比較基準およびプロセスを策定する** |  | 10d | 2005-07-06 | 2005-07-19 |  | 0d |  | 680h |
| 15 | 2.2.1 | 業者選定に関する技術仕様を作成する |  | 1w | 2005-07-06 | 2005-07-12 | 13 | 0d | 製品技術; 購買; 生産技術 | 120h |
| 16 | 2.2.2 | 業者選定に関するサプライチェーン物流パフォーマンス基準を作成する |  | 1w | 2005-07-06 | 2005-07-12 | 15SS | 0d | 購買; 生産技術; プロセスエンジニア | 120h |
| 17 | 2.2.3 | 業者選定に関する財務安定性基準を作成する |  | 1w | 2005-07-06 | 2005-07-12 | 15SS | 0d | 経理; 購買 | 80h |
| 18 | 2.2.4 | 業者選定に関する品質基準を作成する |  | 1w | 2005-07-06 | 2005-07-12 | 15SS | 0d | 購買; 製品技術 | 80h |
| 19 | 2.2.5 | 業者の販売およびカスタマーサービス基準を作成する |  | 1w | 2005-07-06 | 2005-07-12 | 15SS | 0d | マーケティング; 購買 | 80h |
| 20 | 2.2.6 | 業者のグローバルプレゼンス基準を作成する |  | 1w | 2005-07-06 | 2005-07-12 | 15SS | 0d | 購買; 生産技術 | 80h |
| 21 | 2.2.7 | リスク評価基準を特定する |  | 1w | 2005-07-06 | 2005-07-12 | 15SS | 152.5d | 購買; 経理 | 80h |
| 22 | 2.2.8 | 業者比較のための優先順位付けおよびスコア付けの方針を策定する |  | 1w | 2005-07-13 | 2005-07-19 | 15, 16, 17, 18, 19, 20 | 0d | 購買 | 40h |
| 23 | 2.2.9 | 比較基準およびプロセス策定完了 | milestone | 0d | 2005-07-19 | 2005-07-19 | 22 | 147.5d |  |  |
| 24 | 3 | **業者の選定** |  | 167.5d | 2005-06-22 | 2006-02-10 |  | 0d |  | 1570.67h |
| 25 | 3.1 | 業者選定チームを組織し、キックオフ会議を開催する |  | 1d | 2005-06-22 | 2005-06-22 | 6 | 19d | 購買 | 8h |

Notes:
- 1: 調査フェーズでは、自社における業者の利用パターン、利用ニーズ、および業界におけるアウトソーシングのトレンドなどを調査します。
- 2: ここでは、評価および整理統合活動がビジネスアナリストまたは財務部門スタッフによって開始されることを想定しています。 / 「リソースを割り当てる」タスクとは、業者との仕事の経験があり、対象となる業務について経験のあるスタッフを選定する作業を指します。
- 4: 「範囲」とは、業者評価における基準を指します。/ たとえば、取引の量、過去にアウトソーシングした仕事のパフォーマンス、業者の規模および安定性、所在地 (および距離に起因する問題)、提示価格などがあります。
- 5: 評価は現在取引のある業者に限定して行うのか、業者を選別する差異はどこにあるのか (規模の大小、所在地の遠近など)。
- 11: 業者の分野の例: / オフィス事務支援関連の業者/ 資材購入/ 開発リソース/ ビジネスプロセスに関するコンサルティング/ など
- 14: 基準は、業者との取引に関する経験や業者を利用する対象分野によって異なります。
- 21: たとえば、業者を変更した場合に新しい業者が依頼を遂行しない、などのリスクが考えられます。/ このタスクの目的は、意思決定ができるように、リスクに優先順位を付けることにあります。

| ID | WBS | Task | Type | Duration | Start | Finish | Predecessors | Total slack | Resources | Work |
| --- | --- | --- | --- | --- | --- | --- | --- | --- | --- | --- |
| 26 | 3.2 | **見積もり依頼書 (RFP) の作成と配布** |  | 56d | 2005-07-20 | 2005-10-05 |  | 0d |  | 450.67h |
| 27 | 3.2.1 | 情報を収集する |  | 3w | 2005-07-20 | 2005-08-09 | 25, 22 | 0d | 購買 | 120h |
| 28 | 3.2.2 | クライアントのサンプルグループを特定し、連絡する |  | 1w | 2005-08-10 | 2005-08-16 | 27 | 0d | 購買 | 40h |
| 29 | 3.2.3 | 対象企業を特定する |  | 3w | 2005-08-17 | 2005-09-06 | 28 | 0d | 購買 | 120h |
| 30 | 3.2.4 | RFP要件を再定義する |  | 2w | 2005-09-07 | 2005-09-20 | 29 | 0d | 購買 | 80h |
| 31 | 3.2.5 | RFPを作成する |  | 2w | 2005-09-21 | 2005-10-04 | 30 | 0d | 購買; 法務 | 82.67h |
| 32 | 3.2.6 | RFPを配布する |  | 1d | 2005-10-05 | 2005-10-05 | 31 | 0d | 購買 | 8h |
| 33 | 3.2.7 | RFPの作成と配布完了 | milestone | 0d | 2005-10-05 | 2005-10-05 | 32 | 0d |  |  |
| 34 | 3.3 | **RFPプロセスの終了処理、RFPの回答回収および分析** |  | 17d | 2005-10-06 | 2005-10-28 |  | 0d |  | 96h |
| 35 | 3.3.1 | 業者の回答に関するQAセッションを実施する |  | 2d | 2005-10-06 | 2005-10-07 | 33 | 0d | 購買 | 16h |
| 36 | 3.3.2 | 全業者の回答を回収する | milestone | 0d | 2005-10-14 | 2005-10-14 | 35FS+5d | 0d |  |  |
| 37 | 3.3.3 | 最終的な業者の回答を評価する |  | 2w | 2005-10-17 | 2005-10-28 | 36 | 0d | 購買 | 80h |
| 38 | 3.4 | **整理統合を念頭に置いた業者回答のレビュー** |  | 45d | 2005-10-31 | 2005-12-30 |  | 0d |  | 560h |
| 39 | 3.4.1 | 業者の整理統合シナリオを作成する |  | 5w | 2005-10-31 | 2005-12-02 | 37 | 0d | 購買; マネジメント | 400h |
| 40 | 3.4.2 | 提案を評価し、交渉事項を特定する |  | 1w | 2005-12-05 | 2005-12-09 | 39 | 0d | 購買 | 40h |
| 41 | 3.4.3 | 現行の業者契約について契約解除条項の影響を検討する |  | 1w | 2005-12-12 | 2005-12-16 | 40 | 0d | 購買 | 40h |
| 42 | 3.4.4 | 整理統合および問題対応のシナリオを作成する |  | 2w | 2005-12-19 | 2005-12-30 | 41 | 0d | 購買 | 80h |
| 43 | 3.5 | **新業者の選定** |  | 29.5d | 2006-01-02 | 2006-02-10 |  | 0d |  | 456h |
| 44 | 3.5.1 | 選定および交渉条件を最終化する |  | 2w | 2006-01-02 | 2006-01-13 | 42 | 0d | 購買 | 80h |
| 45 | 3.5.2 | 契約を最終化する |  | 1.5w | 2006-01-16 | 2006-01-25 | 44 | 0d | 購買; 顧客 | 120h |
| 46 | 3.5.3 | 選定にもれた業者に連絡する |  | 1d | 2006-01-25 | 2006-01-26 | 45 | 0d | 購買 | 8h |
| 47 | 3.5.4 | 情報システムを更新する |  | 2w | 2006-01-26 | 2006-02-09 | 46 | 0d | 経理; 製品技術; 情報システム; 購買 | 240h |
| 48 | 3.5.5 | 業者の選定を社内に連絡する |  | 1d | 2006-02-09 | 2006-02-10 | 47 | 0d | 購買 | 8h |
| 49 | 3.6 | 選定完了 | milestone | 0d | 2006-02-10 | 2006-02-10 | 48 | 0d |  |  |
| 50 | 4 | 業者の整理統合完了 | milestone | 0d | 2006-02-10 | 2006-02-10 | 49 | 0d |  |  |

Notes:
- 26: この一連のタスクでは、RFP作成を支援するため、社内リソースから情報を収集します。
- 42: 問題対応シナリオでは、業者が期待されるパフォーマンス条件を満たさない場合、業者の安定性に問題がある場合などを扱います。
- 48: 業者選定のプロセスと結果の連絡が社内に行き渡ること、および最終的に承認を受けた業者のリストが用意され適切な担当者に配布されることを確認します。
