# IFRS移行日における開始貸借対照表の作成

Schedule from MS Project, 2005-06-21 to 2005-08-15.
このテンプレートでは、企業が一般会計原則 (GAAP) から国際財務報告基準 (IFRS) に移行する際に作成する、IFRS移行日における開始貸借対照表について、財務会計の観点から行うべき主な活動を扱います。EUではヨーロッパの株式市場に上場している企業に対し、2005年1月1日以降の期間についてはIFRSに準拠した財務諸表を使用して年次報告を行わなければならないと定めているため、現在多くの企業がこのような作業を行っています。

## Calendars

- Standard: Mon-Fri 08:00-12:00, 13:00-17:00; Sat-Sun off.

## Resources

| Resource |
| --- |
| 会計方針グループ |
| 人事 |
| リスク管理 |
| 経理 |
| CFO/経理担当管理者 |

## Schedule

| ID | WBS | Task | Type | Duration | Start | Finish | Predecessors | Total slack | Resources | Work |
| --- | --- | --- | --- | --- | --- | --- | --- | --- | --- | --- |
| 1 | 1 | **初期計画立案** |  | 5d | 2005-06-21 | 2005-06-27 |  | 0d |  | 80h |
| 2 | 1.1 | プロジェクト計画を作成する |  | 1d | 2005-06-21 | 2005-06-21 |  | 0d | 会計方針グループ | 8h |
| 3 | 1.2 | チームを組織する |  | 1d | 2005-06-22 | 2005-06-22 | 2 | 0d | CFO/経理担当管理者 | 8h |
| 4 | 1.3 | IFRSに関する社内知識を評価する |  | 1d | 2005-06-23 | 2005-06-23 | 3 | 0d | 会計方針グループ; 人事 | 16h |
| 5 | 1.4 | IFRSについて教育が必要かを判断する |  | 1d | 2005-06-24 | 2005-06-24 | 4 | 0d | 会計方針グループ; 人事 | 16h |
| 6 | 1.5 | キックオフ会議を開催する |  | 1d | 2005-06-27 | 2005-06-27 | 5 | 0d | 会計方針グループ; CFO/経理担当管理者; 経理; リスク管理 | 32h |
| 7 | 1.6 | 初期計画立案完了 | milestone | 0d | 2005-06-27 | 2005-06-27 | 6 | 0d |  |  |
| 8 | 2 | **IFRSに基づいた報告関作成に関連した現在の「ベストプラクティス」の特定** |  | 2d | 2005-06-28 | 2005-06-29 |  | 0d |  | 24h |
| 9 | 2.1 | 外部監査人/その他のソースからIFRSに基づいた報告作成のマニュアル/ガイドを入手する |  | 1d | 2005-06-28 | 2005-06-28 | 7 | 0d | 会計方針グループ | 8h |
| 10 | 2.2 | 競合他社がIFRSに基づいて申告した財務情報を入手してレビューする |  | 1d | 2005-06-28 | 2005-06-28 | 7 | 0d | 会計方針グループ | 8h |
| 11 | 2.3 | 外部監査人にIFRSに関するベストプラクティスについての意見を求める |  | 1d | 2005-06-29 | 2005-06-29 | 9, 10 | 0d | 会計方針グループ | 8h |
| 12 | 2.4 | 現在のベストプラクティスのレビュー完了 | milestone | 0d | 2005-06-29 | 2005-06-29 | 11 | 0d |  |  |
| 13 | 3 | **使用するIFRS会計方針の特定** |  | 7d | 2005-06-30 | 2005-07-08 |  | 0d |  | 64h |
| 14 | 3.1 | 以前GAAPの下で使用していた会計方針で、IFRSでも使用できるものを特定する |  | 1d | 2005-06-30 | 2005-06-30 | 12 | 0d | 会計方針グループ | 8h |
| 15 | 3.2 | 以前GAAPの下で使用していた会計方針で、IFRSでは使用できないものを特定する |  | 1d | 2005-06-30 | 2005-06-30 | 11 | 0d | 会計方針グループ | 8h |
| 16 | 3.3 | 会計手法が選択できる基準を特定し、手法を選択する |  | 1d | 2005-06-30 | 2005-06-30 | 11 | 0d | 会計方針グループ | 8h |
| 17 | 3.4 | 必要な遡及適用において追加的に情報が必要になる分野を特定する |  | 1d | 2005-07-01 | 2005-07-01 | 14, 15, 16 | 0d | 会計方針グループ | 8h |
| 18 | 3.5 | 追加的な情報の入手を各部門に依頼する |  | 1d | 2005-07-04 | 2005-07-04 | 17 | 0d | 会計方針グループ | 8h |
| 19 | 3.6 | 会計処理において重大な判断/見積もりが必要な分野/項目を特定する |  | 1d | 2005-07-05 | 2005-07-05 | 18 | 0d | CFO/経理担当管理者 | 8h |
| 20 | 3.7 | 内部/外部監査とともにこれらの分野の最終的な会計処理を決定する |  | 1d | 2005-07-06 | 2005-07-06 | 19 | 0d | CFO/経理担当管理者 | 8h |
| 21 | 3.8 | IFRS会計方針マニュアルを作成する |  | 1d | 2005-07-07 | 2005-07-07 | 20 | 0d | 会計方針グループ | 8h |
| 22 | 3.9 | 使用するIFRS会計方針の特定完了 |  | 1d | 2005-07-08 | 2005-07-08 | 21 | 0d |  |  |
| 23 | 4 | **適用するIFRS第1号の免除条項の特定** |  | 10d | 2005-07-11 | 2005-07-22 |  | 0d |  | 80h |
| 24 | 4.1 | 過去の企業結合をレビューし、2004年1月1日以前の結合をIFRS第3号に合わせて再申告すべきかを決定する |  | 1d | 2005-07-11 | 2005-07-11 | 22 | 0d | 会計方針グループ | 8h |
| 25 | 4.2 | 企業が2004年1月1日の特定の資産についてみなし原価に公正価値を使用するかを決定する |  | 1d | 2005-07-12 | 2005-07-12 | 24 | 0d | 会計方針グループ | 8h |
| 26 | 4.3 | IAS第19号に基づいた従業員給付の評価を外部の保険計理士に依頼すべきかを決定する |  | 1d | 2005-07-13 | 2005-07-13 | 25 | 0d | 会計方針グループ | 8h |
| 27 | 4.4 | 移行日における未認識の保険数理差損益の扱いを決定する |  | 1d | 2005-07-14 | 2005-07-14 | 26 | 0d | 会計方針グループ | 8h |
| 28 | 4.5 | 海外子会社の連結による累積換算差額の扱いを決定する |  | 1d | 2005-07-15 | 2005-07-15 | 27 | 0d | 会計方針グループ | 8h |
| 29 | 4.6 | 複合金融商品を特定し、負債部分と資本部分を別にする必要を判定する |  | 1d | 2005-07-18 | 2005-07-18 | 28 | 0d | 会計方針グループ | 8h |
| 30 | 4.7 | 子会社、関連会社、およびジョイントベンチャーの資産/負債を評価する |  | 1d | 2005-07-19 | 2005-07-19 | 29 | 0d | 会計方針グループ | 8h |
| 31 | 4.8 | 移行日における金融商品に関する指定を決定する |  | 1d | 2005-07-20 | 2005-07-20 | 30 | 0d | 会計方針グループ | 8h |
| 32 | 4.9 | 付与日付および移行日において付与されていたかどうかに基づいて株式報酬制度の処理に対する遡及会計処理を決定する |  | 1d | 2005-07-21 | 2005-07-21 | 31 | 0d | 会計方針グループ | 8h |
| 33 | 4.10 | 保険契約に関連するIFRS第4号の暫定条項を適用するかを決定する |  | 1d | 2005-07-22 | 2005-07-22 | 32 | 0d | 会計方針グループ | 8h |
| 34 | 4.11 | 適用するIFRS 1の免除条項の特定完了 | milestone | 0d | 2005-07-22 | 2005-07-22 | 33 | 0d |  |  |

Notes:
- 13: 企業は、IFRSの開始貸借対照表 (2004年12月31日) およびIFRSに基づいた最初の財務諸表に含むすべての期について同じ会計方針を採用しなければなりません。最初のIFRS財務諸表に採用する会計方針は、報告日 (2005年12月31日) において有効であるIFRS基準に準拠している必要があります。ただし、特定の免除または例外事項が適用される場合はこの限りではありません。
- 16: 例: 在庫、資産、生産設備、借入コスト、無形資産、金融商品、投資財産などの会計。
- 17: 例: 社内開発コストの資本化。
- 24: 企業は、2004年1月1日以前の企業結合についてはIFRS第3号に基づく申告を行う義務はありませんが、申告する場合はIFRS第3号が以後すべての企業結合に適用されます。
- 25: 例: 資産、生産設備、無形資産、投資財産。

| ID | WBS | Task | Type | Duration | Start | Finish | Predecessors | Total slack | Resources | Work |
| --- | --- | --- | --- | --- | --- | --- | --- | --- | --- | --- |
| 35 | 5 | **他のIFRSの遡及適用に関する例外の特定** |  | 7d | 2005-07-25 | 2005-08-02 |  | 0d |  | 56h |
| 36 | 5.1 | IAS第39号およびIFRS第4号に関する移行日を決定する |  | 1d | 2005-07-25 | 2005-07-25 | 34 | 0d | 会計方針グループ | 8h |
| 37 | 5.2 | IAS第39号への移行日における金融資産/負債の認識中止の要件を適用する |  | 1d | 2005-07-26 | 2005-07-26 | 36 | 0d | 会計方針グループ | 8h |
| 38 | 5.3 | 以前のGAAPの下で存在していたヘッジ関係を特定する |  | 1d | 2005-07-27 | 2005-07-27 | 37 | 0d | リスク管理 | 8h |
| 39 | 5.4 | バランスシートのすべてのデリバティブを公正価値で認識する |  | 1d | 2005-07-28 | 2005-07-28 | 38 | 0d | 経理 | 8h |
| 40 | 5.5 | IFRSの下でヘッジ会計が適用される場合、適切な文書/有効性検査を用意する |  | 1d | 2005-07-29 | 2005-07-29 | 39 | 0d | リスク管理 | 8h |
| 41 | 5.6 | 以前のGAAPの下で行った推定値の誤りを特定する |  | 1d | 2005-08-01 | 2005-08-01 | 40 | 0d | 会計方針グループ | 8h |
| 42 | 5.7 | 売却目的で保有する資産および廃止事業に関して適切な会計処理を決定する |  | 1d | 2005-08-02 | 2005-08-02 | 41 | 0d | 会計方針グループ | 8h |
| 43 | 5.8 | 例外の特定完了 | milestone | 0d | 2005-08-02 | 2005-08-02 | 42 | 0d |  |  |
| 44 | 6 | **移行調整の準備およびIFRSに基づいた開始貸借対照表の作成** |  | 8d | 2005-08-03 | 2005-08-12 |  | 0d |  | 72h |
| 45 | 6.1 | IFRSで認識が義務付けられているすべての資産および負債を認識する |  | 1d | 2005-08-03 | 2005-08-03 | 43 | 0d | 経理 | 8h |
| 46 | 6.2 | IFRSで認識が許されない資産または負債の認識を中止する |  | 1d | 2005-08-04 | 2005-08-04 | 45 | 0d | 経理 | 8h |
| 47 | 6.3 | IFRSに基づいて資産、負債、資本を再分類する |  | 1d | 2005-08-05 | 2005-08-05 | 46 | 0d | 経理 | 8h |
| 48 | 6.4 | 認識対象のすべての資産および負債について、IFRSを適用した測定を行う |  | 1d | 2005-08-08 | 2005-08-08 | 47 | 0d | 経理 | 8h |
| 49 | 6.5 | 必要に応じて期首利益剰余金またはその他の勘定の移行調整に関連した仕分記入を行う |  | 1d | 2005-08-09 | 2005-08-09 | 48 | 0d | 経理 | 8h |
| 50 | 6.6 | 以前のGAAPの下で報告された資本と移行日におけるIFRSに基づいた資本との間の調整計算を用意する |  | 1d | 2005-08-10 | 2005-08-10 | 49 | 0d | 経理; 会計方針グループ | 16h |
| 51 | 6.7 | IFRSに基づいた開始貸借対照表をレビューする |  | 1d | 2005-08-11 | 2005-08-11 | 50 | 0d | CFO/経理担当管理者 | 8h |
| 52 | 6.8 | 外部監査人に提出し、検査および検証を受ける |  | 1d | 2005-08-12 | 2005-08-12 | 51 | 0d | CFO/経理担当管理者 | 8h |
| 53 | 6.9 | 移行調整およびIFRSに基づいた開始貸借対照表完成 | milestone | 0d | 2005-08-12 | 2005-08-12 | 52 | 0d |  |  |
| 54 | 7 | IFRS移行日における開始貸借対照表の作成完了 |  | 1d | 2005-08-15 | 2005-08-15 | 53 | 0d |  |  |
