# 年次報告書作成

Schedule from MS Project, 2005-10-03 to 2005-11-30.
このテンプレートは、年次報告書作成に関して財務会計部門が行う一般的な作業を扱います。このテンプレートでは、複数部門から情報を入手する作業、必要な情報を正確に提示するための他部門 (法務、広報など) との協力から、最終的な印刷、配布まですべてを通して扱います。

## Calendars

- Standard: Mon-Fri 08:00-12:00, 13:00-17:00; Sat-Sun off.

## Resources

| Resource |
| --- |
| 監査委員会 |
| 法務部門 |
| 外部監査人 |
| 実行委員会 |
| CFO/経理担当管理者 |
| マーケティンググループ |
| 戦略企画委員会 |
| PR/IR部門 |
| 会長 |

## Schedule

| ID | WBS | Task | Type | Duration | Start | Finish | Predecessors | Total slack | Free slack | Resources | Work |
| --- | --- | --- | --- | --- | --- | --- | --- | --- | --- | --- | --- |
| 1 | 1 | **計画立案** |  | 6d | 2005-10-03 | 2005-10-10 |  | 0d |  |  | 48h |
| 2 | 1.1 | 前年度の年次報告書作成プロセスのプロジェクトファイルおよび教訓をレビューする |  | 1d | 2005-10-03 | 2005-10-03 |  | 0d |  | 戦略企画委員会 | 8h |
| 3 | 1.2 | 財務報告要件について変更があるか確認する |  | 1d | 2005-10-04 | 2005-10-04 | 2 | 0d |  | CFO/経理担当管理者 | 8h |
| 4 | 1.3 | 年次報告書のテーマおよびセクションの要件を洗い出す |  | 1d | 2005-10-05 | 2005-10-05 | 3 | 0d |  | 戦略企画委員会 | 8h |
| 5 | 1.4 | 他に追加または削除するセクションを確認する |  | 1d | 2005-10-06 | 2005-10-06 | 4 | 0d |  | 戦略企画委員会 | 8h |
| 6 | 1.5 | SEC提出書類と年次報告書のチェック項目を確認する |  | 1d | 2005-10-07 | 2005-10-07 | 5 | 0d |  | CFO/経理担当管理者 | 8h |
| 7 | 1.6 | 内部監査人を選定する |  | 1d | 2005-10-10 | 2005-10-10 | 6 | 0d |  | 監査委員会 | 8h |
| 8 | 1.7 | 計画立案完了 | milestone | 0d | 2005-10-10 | 2005-10-10 | 7 | 0d |  |  |  |
| 9 | 2 | **年次報告書の構成設計** |  | 6d | 2005-10-11 | 2005-10-18 |  | 0d |  |  | 48h |
| 10 | 2.1 | 基本構成設計に必要なリソースを割り当てる |  | 1d | 2005-10-11 | 2005-10-11 | 8 | 0d |  | 戦略企画委員会 | 8h |
| 11 | 2.2 | 基本構成設計および情報に関する要件を洗い出す |  | 1d | 2005-10-12 | 2005-10-12 | 10 | 0d |  | 戦略企画委員会 | 8h |
| 12 | 2.3 | **報告書の配布方法を評価/確認する** |  | 3d | 2005-10-13 | 2005-10-17 |  | 0d |  |  | 24h |
| 13 | 2.3.1 | 年次報告書の構成および配布業者を評価/確認する |  | 1d | 2005-10-13 | 2005-10-13 | 11 | 0d |  | PR/IR部門 | 8h |
| 14 | 2.3.2 | 企業サイトの設計および統合要件を評価/確認する |  | 1d | 2005-10-14 | 2005-10-14 | 13 | 0d |  | PR/IR部門 | 8h |
| 15 | 2.3.3 | 年次報告書の制作および配送業者を評価/確認する |  | 1d | 2005-10-17 | 2005-10-17 | 14 | 0d |  | PR/IR部門 | 8h |
| 16 | 2.3.4 | 確認された配布方法を報告する | milestone | 0d | 2005-10-17 | 2005-10-17 | 15 | 0d |  | PR/IR部門 |  |
| 17 | 2.4 | 作成スケジュールを計画し、確認する |  | 1d | 2005-10-18 | 2005-10-18 | 16 | 0d |  | PR/IR部門 | 8h |
| 18 | 2.5 | 年次報告書の構成設計完了 | milestone | 0d | 2005-10-18 | 2005-10-18 | 17 | 0d |  |  |  |
| 19 | 3 | **SEC 10-Kおよび株主総会召集通知書の制作スケジュールの作成** |  | 3d | 2005-10-19 | 2005-10-21 |  | 0d |  |  | 24h |
| 20 | 3.1 | 10-Kの制作スケジュールを計画/確認する |  | 1d | 2005-10-19 | 2005-10-19 | 18 | 0d |  | CFO/経理担当管理者 | 8h |
| 21 | 3.2 | 株主総会召集通知書の制作スケジュールを計画/確認する |  | 1d | 2005-10-20 | 2005-10-20 | 20 | 0d |  | CFO/経理担当管理者 | 8h |
| 22 | 3.3 | 制作スケジュールを予定通り進めるために必要な手順を洗い出す |  | 1d | 2005-10-21 | 2005-10-21 | 21 | 0d |  | CFO/経理担当管理者 | 8h |
| 23 | 3.4 | SEC 10-Kおよび株主総会召集通知書の制作スケジュール作成完了 | milestone | 0d | 2005-10-21 | 2005-10-21 | 22 | 0d |  |  |  |
| 24 | 4 | **年次報告書の作成** |  | 23d | 2005-10-24 | 2005-11-23 |  | 4.5d |  |  | 216h |
| 25 | 4.1 | **テーマ別コンポーネントの作成** |  | 7d | 2005-10-24 | 2005-11-01 |  | 16.5d |  |  | 56h |
| 26 | 4.1.1 | テーマ内容作成セッションを計画し、開催する |  | 1d | 2005-10-24 | 2005-10-24 | 23 | 16.5d | 0d | PR/IR部門 | 8h |
| 27 | 4.1.2 | テーマに関する統計情報を収集し、テーマのメッセージを実証する |  | 1d | 2005-10-25 | 2005-10-25 | 26 | 16.5d | 0d | PR/IR部門 | 8h |
| 28 | 4.1.3 | テーマ関係者にインタビューする |  | 1d | 2005-10-26 | 2005-10-26 | 27 | 16.5d | 0d | PR/IR部門 | 8h |
| 29 | 4.1.4 | テーマセクションの記事の草稿を作成する |  | 1d | 2005-10-27 | 2005-10-27 | 28 | 16.5d | 0d | PR/IR部門 | 8h |
| 30 | 4.1.5 | テーマに関する写真およびWebサイト設計のセッションを計画する |  | 1d | 2005-10-28 | 2005-10-28 | 29 | 16.5d | 0d | PR/IR部門 | 8h |
| 31 | 4.1.6 | テーマに関する事実関係を検証する |  | 1d | 2005-10-31 | 2005-10-31 | 30 | 16.5d | 0d | PR/IR部門 | 8h |
| 32 | 4.1.7 | 経営幹部の指揮の下でテーマの構成および記事を最終化する |  | 1d | 2005-11-01 | 2005-11-01 | 31 | 16.5d | 0d | PR/IR部門 | 8h |
| 33 | 4.1.8 | テーマ制作完了 | milestone | 0d | 2005-11-01 | 2005-11-01 | 32 | 16.5d | 0d |  |  |

Notes:
- 4: テーマを定義したら、テーマ内容に基づき関係者のリストを作成します。

| ID | WBS | Task | Type | Duration | Start | Finish | Predecessors | Total slack | Free slack | Resources | Work |
| --- | --- | --- | --- | --- | --- | --- | --- | --- | --- | --- | --- |
| 34 | 4.2 | **株主への手紙の作成** |  | 16d | 2005-11-02 | 2005-11-23 |  | 4.5d |  |  | 40h |
| 35 | 4.2.1 | 会長/CEOとのインタビューを計画する |  | 1d | 2005-11-02 | 2005-11-02 | 33 | 16.5d | 0d | PR/IR部門 | 8h |
| 36 | 4.2.2 | インタビューを実施する |  | 1d | 2005-11-03 | 2005-11-03 | 35 | 16.5d | 0d | PR/IR部門; 会長 | 16h |
| 37 | 4.2.3 | 手紙を作成し、レビューする |  | 1d | 2005-11-04 | 2005-11-04 | 36 | 16.5d | 12d | PR/IR部門 | 8h |
| 38 | 4.2.4 | 手紙を監査済みの決算発表内容と突き合わせてレビューする |  | 1d | 2005-11-23 | 2005-11-23 | 37, 83 | 4.5d | 0d | PR/IR部門 | 8h |
| 39 | 4.2.5 | 株主への手紙完成 | milestone | 0d | 2005-11-23 | 2005-11-23 | 38 | 4.5d |  |  |  |
| 40 | 4.3 | **PRおよびIR関連コンポーネントの作成** |  | 11.5d | 2005-11-08 | 2005-11-23 |  | 0d |  |  | 120h |
| 41 | 4.3.1 | **PRおよびIRのマイルストーンの設定** |  | 0.5d | 2005-11-08 | 2005-11-08 |  | 0d |  |  | 4h |
| 42 | 4.3.1.1 | PRおよびIRについて主なマイルストーンを定義する (成果物と調整する) |  | 0.5d | 2005-11-08 | 2005-11-08 | 76 | 0d |  | PR/IR部門 | 4h |
| 43 | 4.3.2 | **PRメッセージの作成** |  | 3.5d | 2005-11-08 | 2005-11-11 |  | 11d |  |  | 28h |
| 44 | 4.3.2.1 | 年次報告書に掲載するPRメッセージの内容を決める |  | 0.5d | 2005-11-08 | 2005-11-08 | 42 | 11d | 0d | PR/IR部門 | 4h |
| 45 | 4.3.2.2 | 財務結果に関するPRメッセージの内容を決める |  | 2d | 2005-11-09 | 2005-11-10 | 44 | 11d | 0d | PR/IR部門 | 16h |
| 46 | 4.3.2.3 | 配布チャネルおよび日程の詳細を詰める |  | 1d | 2005-11-11 | 2005-11-11 | 45 | 11d | 7d | PR/IR部門 | 8h |
| 47 | 4.3.3 | **IRメッセージの作成** |  | 11d | 2005-11-08 | 2005-11-23 |  | 0d |  |  | 88h |
| 48 | 4.3.3.1 | 年次報告書に掲載するIRメッセージの内容を決める |  | 2d | 2005-11-08 | 2005-11-10 | 42 | 9.5d | 0d | PR/IR部門 | 16h |
| 49 | 4.3.3.2 | 財務結果に関するIRメッセージの内容を決める |  | 2d | 2005-11-10 | 2005-11-14 | 48 | 9.5d | 0d | PR/IR部門 | 16h |
| 50 | 4.3.3.3 | 年次報告書の配布チャネルおよび日程の詳細を詰める |  | 2d | 2005-11-14 | 2005-11-16 | 49 | 9.5d | 4.5d | PR/IR部門 | 16h |
| 51 | 4.3.3.4 | CFOから財務結果を入手する |  | 0.5d | 2005-11-23 | 2005-11-23 | 50, 83 | 5d |  | PR/IR部門; CFO/経理担当管理者 | 8h |
| 52 | 4.3.3.5 | **株主の配布リストの入手および配布プロセスを確認する** |  | 4d | 2005-11-08 | 2005-11-14 |  | 0d |  |  | 32h |
| 53 | 4.3.3.5.1 | 機関投資家の配布リスト/プロセスを確認する |  | 1d | 2005-11-08 | 2005-11-09 | 42 | 0d |  | PR/IR部門 | 8h |
| 54 | 4.3.3.5.2 | 仲介業者のの配布リスト/プロセスを確認する |  | 1d | 2005-11-09 | 2005-11-10 | 53 | 0d |  | PR/IR部門 | 8h |
| 55 | 4.3.3.5.3 | 個人投資家のの配布リスト/プロセスを確認する |  | 1d | 2005-11-10 | 2005-11-11 | 54 | 0d |  | PR/IR部門 | 8h |
| 56 | 4.3.3.5.4 | 企業サイトの更新/フォーマット/記事投稿プロセスを確認する |  | 1d | 2005-11-11 | 2005-11-14 | 55 | 0d |  | PR/IR部門 | 8h |
| 57 | 4.3.3.5.5 | 投稿・配布プロセス確認完了 | milestone | 0d | 2005-11-14 | 2005-11-14 | 56 | 0d |  |  |  |
| 58 | 4.3.4 | PRおよびIR関連メッセージ作成・計画完了 | milestone | 0d | 2005-11-14 | 2005-11-14 | 57 | 0d |  |  |  |

| ID | WBS | Task | Type | Duration | Start | Finish | Predecessors | Total slack | Free slack | Resources | Work | Text3 | Text4 | Text5 |
| --- | --- | --- | --- | --- | --- | --- | --- | --- | --- | --- | --- | --- | --- | --- |
| 59 | 5 | **決算活動の実施** |  | 23.5d | 2005-10-24 | 2005-11-24 |  | 0d |  |  | 216h |  |  |  |
| 60 | 5.1 | **財務概況コンポーネントおよび関連SEC提出書類のスケジュールを設定する** |  | 5d | 2005-10-24 | 2005-10-28 |  | 0d |  |  | 48h |  |  |  |
| 61 | 5.1.1 | 決算スケジュールを作成する |  | 1d | 2005-10-24 | 2005-10-24 | 23 | 0d |  | CFO/経理担当管理者 | 8h |  |  |  |
| 62 | 5.1.2 | 外部監査スケジュールを作成し、確認する |  | 1d | 2005-10-25 | 2005-10-25 | 61 | 0d |  | CFO/経理担当管理者; 外部監査人 | 16h |  |  |  |
| 63 | 5.1.3 | 決算報告を作成、確認するためのリソースを洗い出し、割り当てる |  | 1d | 2005-10-26 | 2005-10-26 | 62 | 0d |  | CFO/経理担当管理者 | 8h |  |  |  |
| 64 | 5.1.4 | 10-Kセクションを作成、確認するためのリソースを洗い出し、割り当てる |  | 1d | 2005-10-27 | 2005-10-27 | 63 | 0d |  | CFO/経理担当管理者 | 8h |  |  |  |
| 65 | 5.1.5 | 株主総会召集通知書セクションを作成、確認するためのリソースを洗い出し、割り当てる |  | 1d | 2005-10-28 | 2005-10-28 | 64 | 0d |  | CFO/経理担当管理者 | 8h |  |  |  |
| 66 | 5.1.6 | 財務概況および関連SEC提出書類のスケジュール作成完了 | milestone | 0d | 2005-10-28 | 2005-10-28 | 65 | 0d |  |  |  |  |  |  |
| 67 | 5.2 | **決算を実施する** |  | 3d | 2005-10-31 | 2005-11-02 |  | 0d |  |  | 24h |  |  |  |
| 68 | 5.2.1 | 期末の帳簿を締め切る |  | 1d | 2005-10-31 | 2005-10-31 | 66 | 0d |  | CFO/経理担当管理者 | 8h |  |  |  |
| 69 | 5.2.2 | 財務調整 (未収支および引き当て) のレビューおよび承認を行う |  | 1d | 2005-11-01 | 2005-11-01 | 68 | 0d |  | CFO/経理担当管理者 | 8h |  |  |  |
| 70 | 5.2.3 | 年次報告書、10-K、および株主総会召集通知書に掲載する決算報告を作成する |  | 1d | 2005-11-02 | 2005-11-02 | 69 | 0d |  | CFO/経理担当管理者 | 8h |  |  |  |
| 71 | 5.2.4 | 決算および決算報告作成完了 | milestone | 0d | 2005-11-02 | 2005-11-02 | 70 | 0d |  |  |  |  |  |  |
| 72 | 5.3 | **財務諸表の脚注およびSEC提出書類を作成する** |  | 3d | 2005-11-03 | 2005-11-07 |  | 0d |  |  | 24h |  |  |  |
| 73 | 5.3.1 | 財務諸表の脚注のドラフトを作成する |  | 1d | 2005-11-03 | 2005-11-03 | 71 | 0d |  | CFO/経理担当管理者 | 8h |  |  |  |
| 74 | 5.3.2 | 10-Kのドラフトを作成する |  | 1d | 2005-11-04 | 2005-11-04 | 73 | 0d |  | CFO/経理担当管理者 | 8h |  |  |  |
| 75 | 5.3.3 | 株主総会召集通知書情報のドラフトを作成する |  | 1d | 2005-11-07 | 2005-11-07 | 74 | 0d |  | 法務部門 | 8h |  |  |  |
| 76 | 5.3.4 | 財務諸表の脚注およびSEC提出書類のドラフト作成完了 | milestone | 0d | 2005-11-07 | 2005-11-07 | 75 | 0d |  |  |  |  |  |  |
| 77 | 5.4 | **外部監査を実施する** |  | 4d | 2005-11-17 | 2005-11-22 |  | 4d |  |  | 56h | Mfg and Tech | Internal Mfg | Guadalajara |
| 78 | 5.4.1 | 海外および子会社の会計監査を実施する |  | 1d | 2005-11-17 | 2005-11-17 | 91 | 4d | 0d | 外部監査人 | 8h |  |  |  |
| 79 | 5.4.2 | 企業会計監査を実施する |  | 1d | 2005-11-18 | 2005-11-18 | 78 | 4d | 0d | 外部監査人 | 8h |  |  |  |
| 80 | 5.4.3 | 外部監査完了 | milestone | 0d | 2005-11-18 | 2005-11-18 | 79 | 4d | 0d |  |  |  |  |  |
| 81 | 5.4.4 | 監査委員会とともに監査結果をレビューし、最終化する |  | 1d | 2005-11-21 | 2005-11-21 | 80 | 4d | 0d | 外部監査人; CFO/経理担当管理者; 監査委員会 | 24h |  |  |  |
| 82 | 5.4.5 | 決算報告書を承認する/シニアマネジメントの承認を受ける |  | 1d | 2005-11-22 | 2005-11-22 | 81 | 4d | 0d | 監査委員会; CFO/経理担当管理者 | 16h |  |  |  |
| 83 | 5.4.6 | 外部監査完了 | milestone | 0d | 2005-11-22 | 2005-11-22 | 82 | 4d | 0d |  |  |  |  |  |

Notes:
- 61: スケジュールは、決算を行い、年次報告書および10-Kに必要な財務諸表情報を用意するためのマイルストーンの達成に必要な時間およびリソースに基づいて作成します。 / つまり、先に期日を決めてから、その期日を守るために活動を開始しなければならない日を決めます。
- 77: 外部会計監査は年間を通して行われます。監査活動は、期末の決算に基づいて年次報告書および決算報告書が作成され、外部監査人がこれらを承認するまでに焦点を合わせて行われます。

| ID | WBS | Task | Type | Duration | Start | Finish | Predecessors | Total slack | Free slack | Resources | Work |
| --- | --- | --- | --- | --- | --- | --- | --- | --- | --- | --- | --- |
| 84 | 5.5 | **内部法務レビューを実施する** |  | 7d | 2005-11-08 | 2005-11-16 |  | 4d |  |  | 48h |
| 85 | 5.5.1 | 年次報告書に含める主要イベントを調整し、レビューする |  | 1d | 2005-11-08 | 2005-11-08 | 76 | 4d | 0d | 法務部門 | 8h |
| 86 | 5.5.2 | 10-Kに含める主要イベントを調整し、レビューする |  | 1d | 2005-11-09 | 2005-11-09 | 85 | 4d | 0d | 法務部門 | 8h |
| 87 | 5.5.3 | 株主総会召集通知書を調整し、作成する |  | 1d | 2005-11-10 | 2005-11-10 | 86 | 4d | 0d | 法務部門 | 8h |
| 88 | 5.5.4 | 株主へのメッセージを調整し、レビューする |  | 1d | 2005-11-11 | 2005-11-11 | 87 | 4d | 0d | 法務部門 | 8h |
| 89 | 5.5.5 | 外部監査レビューおよびコメントを調整し、レビューする |  | 1d | 2005-11-14 | 2005-11-14 | 88 | 4d | 0d | 法務部門 | 8h |
| 90 | 5.5.6 | シニアマネジメントの承認を調整し、レビューする |  | 1d | 2005-11-15 | 2005-11-15 | 89 | 4d | 0d | 法務部門 | 8h |
| 91 | 5.5.7 | 内部法務レビュー完了 |  | 1d | 2005-11-16 | 2005-11-16 | 90 | 4d | 0d |  |  |
| 92 | 5.6 | 決算内容を公表する |  | 0.5d | 2005-11-23 | 2005-11-23 | 46, 83 | 4d | 0d | 監査委員会; CFO/経理担当管理者; 会長; PR/IR部門 | 16h |
| 93 | 5.7 | 決算完了 |  | 1d | 2005-11-23 | 2005-11-24 | 92 | 4d |  |  |  |
| 94 | 6 | **年次報告書制作** |  | 8d | 2005-11-14 | 2005-11-24 |  | 0d |  |  | 64h |
| 95 | 6.1 | 年次報告書の構成レイアウトのドラフトを作成し、プレースホルダを指定する |  | 1d | 2005-11-14 | 2005-11-15 | 58 | 0d |  | PR/IR部門 | 8h |
| 96 | 6.2 | 経営陣用のモックアップを作成する |  | 1d | 2005-11-15 | 2005-11-16 | 95 | 0d |  | PR/IR部門 | 8h |
| 97 | 6.3 | 設計を繰り返す/制作スケジュールを最終化する |  | 1d | 2005-11-16 | 2005-11-17 | 96 | 0d |  | PR/IR部門 | 8h |
| 98 | 6.4 | 年次報告書の構成およびプレースホルダのデータを最終化する |  | 1d | 2005-11-17 | 2005-11-18 | 97 | 0d |  | PR/IR部門 | 8h |
| 99 | 6.5 | 最終的なレイアウトを作成する/最終承認を得る |  | 1d | 2005-11-18 | 2005-11-21 | 98 | 0d |  | PR/IR部門 | 8h |
| 100 | 6.6 | 年次報告書を印刷する |  | 1d | 2005-11-21 | 2005-11-22 | 99 | 0d |  | PR/IR部門 | 8h |
| 101 | 6.7 | 10-Kの文書ファイルを入手する |  | 1d | 2005-11-22 | 2005-11-23 | 100 | 0d |  | PR/IR部門 | 8h |
| 102 | 6.8 | 株主総会召集通知書の文書ファイルを入手する |  | 1d | 2005-11-23 | 2005-11-24 | 101 | 0d |  | PR/IR部門 | 8h |
| 103 | 6.9 | 年次報告書の制作完了 | milestone | 0d | 2005-11-24 | 2005-11-24 | 102 | 0d |  |  |  |
| 104 | 7 | **年次報告書の配布** |  | 4d | 2005-11-24 | 2005-11-30 |  | 0d |  |  | 32h |
| 105 | 7.1 | 最終的な配布リストを入手する |  | 1d | 2005-11-24 | 2005-11-25 | 103 | 0d |  | PR/IR部門 | 8h |
| 106 | 7.2 | 年次報告書配送用の10-Kを印刷する |  | 1d | 2005-11-25 | 2005-11-28 | 105 | 0d |  | PR/IR部門 | 8h |
| 107 | 7.3 | 年次報告書配送用の株主総会召集通知書を印刷する |  | 1d | 2005-11-28 | 2005-11-29 | 106 | 0d |  | PR/IR部門 | 8h |
| 108 | 7.4 | 年次報告書関連配送物をまとめ、配送する |  | 1d | 2005-11-29 | 2005-11-30 | 107 | 0d |  | PR/IR部門 | 8h |
| 109 | 7.5 | 配送完了 | milestone | 0d | 2005-11-30 | 2005-11-30 | 108 | 0d |  |  |  |
| 110 | 8 | 年次報告書作業完了 | milestone | 0d | 2005-11-30 | 2005-11-30 | 109 | 0d |  |  |  |
