# Network Switch Installation Template

Schedule from MS Project, 2005-01-03 to 2005-03-22.
Microsoft

## Calendars

- Standard: Mon-Fri 08:00-12:00, 13:00-17:00; Sat-Sun off.

## Resources

| Resource |
| --- |
| 調達業者 |
| プログラムマネージャ |
| ネットワークエンジニア |
| プロジェクト要請者/スポンサー |
| シニアマネジメント |
| グループプログラムマネージャ |
| 現場IT担当者 |
| ケーブル業者 |
| ITマネージャ |

## Schedule

| ID | WBS | Task | Type | Duration | Start | Finish | Predecessors | Total slack | Free slack | Resources | Work | Text20 | Text21 |
| --- | --- | --- | --- | --- | --- | --- | --- | --- | --- | --- | --- | --- | --- |
| 1 | 1 | **MICROSOFT IT - ネットワーク拡張** |  | 57d | 2005-01-03 | 2005-03-22 |  | 0d |  |  | 145.61h |  |  |
| 2 | 1.1 | **プロジェクト発足** |  | 2d | 2005-01-03 | 2005-01-04 |  | 0d |  |  | 16h | Protected |  |
| 3 | 1.1.1 | プロジェクト要件を定義する | milestone | 0d | 2005-01-03 | 2005-01-03 |  | 0d |  | プロジェクト要請者/スポンサー |  |  |  |
| 4 | 1.1.2 | プロジェクトをレビューし、承認する |  | 2d | 2005-01-03 | 2005-01-04 | 3 | 0d |  | シニアマネジメント | 16h | Protected | GPM |
| 5 | 1.1.3 | プログラムマネージャを任命する | milestone | 0d | 2005-01-04 | 2005-01-04 | 4 | 0d |  | グループプログラムマネージャ |  | Protected | PM |
| 6 | 1.2 | **計画** |  | 8d | 2005-01-05 | 2005-01-14 |  | 0d |  |  | 9.44h |  |  |
| 7 | 1.2.1 | プロジェクトに関する情報を収集する |  | 5d | 2005-01-05 | 2005-01-11 | 5 | 0d |  | プログラムマネージャ [10%] | 4h |  |  |
| 8 | 1.2.2 | ネットワークエンジニアを要請し、プロジェクトに配属する |  | 2d | 2005-01-12 | 2005-01-13 | 7 | 0d |  | プログラムマネージャ [10%] | 1.6h |  |  |
| 9 | 1.2.3 | キックオフ会議を開催し、日程と対象範囲に合意する |  | 1d | 2005-01-14 | 2005-01-14 | 7, 8 | 0d |  | プロジェクト要請者/スポンサー [12%]; プログラムマネージャ [12%]; ネットワークエンジニア [12%]; ITマネージャ [12%] | 3.84h |  |  |
| 10 | 1.2.4 | プロジェクトの基本的な枠組み決定 | milestone | 0h | 2005-01-14 | 2005-01-14 | 9 | 0d |  | プログラムマネージャ |  |  |  |
| 11 | 1.3 | **実施・管理** |  | 37d | 2005-01-17 | 2005-03-08 |  | 0d |  |  | 79.46h |  |  |
| 12 | 1.3.1 | **設計** |  | 6d | 2005-01-17 | 2005-01-24 |  | 0d |  |  | 5.04h |  |  |
| 13 | 1.3.1.1 | 設計および作業範囲仕様書 (SOW) を作成し、承認する |  | 5d | 2005-01-17 | 2005-01-21 | 10 | 0d |  | ネットワークエンジニア [10%] | 4h |  |  |
| 14 | 1.3.1.2 | 必要機材の一覧表をPMに提出する |  | 1d | 2005-01-24 | 2005-01-24 | 13 | 0d |  | ネットワークエンジニア [13%] | 1.04h |  |  |
| 15 | 1.3.2 | **ハードウェアの購入** |  | 28.25d | 2005-01-25 | 2005-03-04 |  | 0d |  |  | 20.63h |  |  |
| 16 | 1.3.2.1 | 業者に見積もりを依頼する |  | 2d | 2005-01-25 | 2005-01-26 | 14 | 0d |  | プログラムマネージャ [25%] | 4h |  |  |
| 17 | 1.3.2.2 | 業者から見積もりを受け取る |  | 5d | 2005-01-27 | 2005-02-02 | 16 | 0d |  | プログラムマネージャ [10%] | 4h |  |  |
| 18 | 1.3.2.3 | 業者を選定し、発注する |  | 1d | 2005-02-03 | 2005-02-03 | 17 | 0d |  | プログラムマネージャ [33%] | 2.63h |  |  |
| 19 | 1.3.2.4 | 機材納入までのリードタイム |  | 20d | 2005-02-04 | 2005-03-03 | 18 | 0d |  | 調達業者 [5%] | 8h |  |  |
| 20 | 1.3.2.5 | 機材の納入を受けて検査を行い、現場に保管する |  | 0.25d | 2005-03-04 | 2005-03-04 | 19 | 0d |  | 現場IT担当者 | 2h |  |  |
| 21 | 1.3.3 | **配線** |  | 13d | 2005-02-04 | 2005-02-22 |  | 7.25d |  |  | 36.72h |  |  |
| 22 | 1.3.3.1 | 業者に見積もりを依頼する |  | 2d | 2005-02-04 | 2005-02-07 | 18 | 7.25d | 0d | プログラムマネージャ [25%] | 4h |  |  |
| 23 | 1.3.3.2 | 業者から見積もりを受け取る |  | 5d | 2005-02-08 | 2005-02-14 | 22 | 7.25d | 0d | プログラムマネージャ [10%] | 4h |  |  |
| 24 | 1.3.3.3 | 業者を選定し、発注する |  | 1d | 2005-02-15 | 2005-02-15 | 23 | 7.25d | 0d | プログラムマネージャ [33%] | 2.63h |  |  |
| 25 | 1.3.3.4 | 施設管理部門に作業日および業者の立ち入りについて許可をもらう |  | 2d | 2005-02-16 | 2005-02-17 | 24 | 7.25d | 0d | プログラムマネージャ [13%] | 2.08h |  |  |
| 26 | 1.3.3.5 | 配線作業開始 |  | 3d | 2005-02-18 | 2005-02-22 | 25 | 7.25d | 0d | ケーブル業者 | 24h |  |  |
| 27 | 1.3.3.6 | 配線作業完了 | milestone | 0d | 2005-02-22 | 2005-02-22 | 26 | 7.25d |  | ケーブル業者 |  |  |  |

Notes:
- 7: ネットワーク対応にするフロア部分のデスク配置、新規ユーザの数、ユーザごとのポート数およびプリンタとファクスの数、インストール日、現場連絡先、ケーブル室の詳細 (使用可能なラックスペースなど)、既存の配線の詳細および要件など。
- 9: プロジェクトの範囲、予算、リソース、およびスケジュールに関するプロジェクト計画について、プロジェクトスポンサーを含めたチームメンバー全員の合意を得て計画を承認します。
- 16: ネットワークハードウェアおよび必要な場合はラック、各種ケーブル、および電源ケーブルなど。

| ID | WBS | Task | Type | Duration | Start | Finish | Predecessors | Total slack | Free slack | Resources | Work |
| --- | --- | --- | --- | --- | --- | --- | --- | --- | --- | --- | --- |
| 28 | 1.3.4 | **インストール** |  | 3.75d | 2005-03-03 | 2005-03-08 |  | 3d |  |  | 17.07h |
| 29 | 1.3.4.1 | インストールの事前打ち合わせを行う |  | 0.25d | 2005-03-03 | 2005-03-03 | 33SS-3d | 13.5d |  | プログラムマネージャ; ネットワークエンジニア; ITマネージャ | 6h |
| 30 | 1.3.4.2 | 変更管理通知を提出する |  | 1d | 2005-03-03 | 2005-03-04 | 33SS-3d | 11.75d | 0d | ネットワークエンジニア [13%] | 1.03h |
| 31 | 1.3.4.3 | ITマネージャがエンドユーザにインストール日のサービス停止について知らせる |  | 1d | 2005-03-04 | 2005-03-07 | 30 | 11.75d |  | ITマネージャ [13%] | 1.03h |
| 32 | 1.3.4.4 | **ネットワーク機器の設置と設定** |  | 0.62d | 2005-03-08 | 2005-03-08 |  | 0d |  |  | 8h |
| 33 | 1.3.4.4.1 | 古い機器をラックから外す |  | 1h | 2005-03-08 | 2005-03-08 | 20FS+2d, 27FS+2d | 0d |  | 現場IT担当者 | 1h |
| 34 | 1.3.4.4.2 | 新しい機器を設置する |  | 1h | 2005-03-08 | 2005-03-08 | 33 | 0d |  | 現場IT担当者 | 1h |
| 35 | 1.3.4.4.3 | 新しい機器を設定し、テストする |  | 3h | 2005-03-08 | 2005-03-08 | 34 | 0d |  | ネットワークエンジニア; 現場IT担当者 | 6h |
| 36 | 1.3.4.5 | インストールの完了をITマネージャに知らせる |  | 1h | 2005-03-08 | 2005-03-08 | 35 | 0d |  | プログラムマネージャ | 1h |
| 37 | 1.3.4.6 | 受け入れ承認 | milestone | 0h | 2005-03-08 | 2005-03-08 | 36 | 0d |  | ITマネージャ; プロジェクト要請者/スポンサー |  |
| 38 | 1.4 | **プロジェクトの終了** |  | 10d | 2005-03-09 | 2005-03-22 |  | 0d |  |  | 40.72h |
| 39 | 1.4.1 | IT部門が新しいハードウェアのサポートを引き受ける |  | 1w | 2005-03-09 | 2005-03-15 | 37 | 5d |  | ITマネージャ [10%]; ネットワークエンジニア [10%] | 8h |
| 40 | 1.4.2 | 技術文書および図面を更新し、集中管理する |  | 3d | 2005-03-09 | 2005-03-11 | 37 | 7d |  | ネットワークエンジニア [8%] | 1.92h |
| 41 | 1.4.3 | 会計処理を行う (請求書の提出と支払い) |  | 10d | 2005-03-09 | 2005-03-22 | 37 | 0d |  | プログラムマネージャ [10%] | 8h |
| 42 | 1.4.4 | ハードウェアおよび修理メンテナンス契約があれば更新する |  | 1d | 2005-03-09 | 2005-03-09 | 37 | 9d |  | プログラムマネージャ [25%] | 2h |
| 43 | 1.4.5 | 古い機器の引き取り/破棄を手配する |  | 2d | 2005-03-09 | 2005-03-10 | 37 | 8d |  | プログラムマネージャ [25%] | 4h |
| 44 | 1.4.6 | プロジェクトチームとともにプロジェクト終了レビューを作成し、承認する |  | 10d | 2005-03-09 | 2005-03-22 | 37 | 0d |  | プログラムマネージャ [10%]; プロジェクト要請者/スポンサー [5%]; ネットワークエンジニア [5%]; ITマネージャ [5%] | 16.8h |
| 45 | 1.4.7 | プロジェクト完了 | milestone | 0h | 2005-03-22 | 2005-03-22 | 39, 40, 41, 42, 43, 44 | 0d |  | プログラムマネージャ |  |

Notes:
- 29: インストール日を確認し、ITマネージャに日時と必要な場合はITサービスの停止について承認をもらいます。
- 30: Microsoft社のグローバルネットワーク監視チームに対する通知。特定の日時に当該無線施設のネットワークに変更を加えることを知らせます。通知には対象となる場所と影響を受けるハードウェアが示されます。
- 31: サービス停止がある場合のみ。
