# scenarilo1

Schedule from MS Project, 2005-10-03 to 2005-12-22, A marks actual dates.

## Calendars

- マイクロシステムズ標準カレンダー: Mon-Fri 08:00-12:00, 13:00-17:00; Sat-Sun off. Exceptions (off unless hours are given): 2005-10-10, 2005-11-03, 2005-11-23.

## Schedule

| ID | WBS | Task | Type | Duration | Start | Finish | Predecessors | Complete | Remaining | Baseline start | Baseline finish | Baseline duration | Total slack | Free slack | Deadline | Text1 |
| --- | --- | --- | --- | --- | --- | --- | --- | --- | --- | --- | --- | --- | --- | --- | --- | --- |
| 1 | 1 | 設計完了 | milestone | 0d | 2005-10-27 | 2005-10-27 | 6 |  |  | 2005-10-27 | 2005-10-27 | 0d | 2d |  | 2005-10-31 | 共通 |
| 2 | 2 | 開発完了 | milestone | 0d | 2005-12-01 | 2005-12-01 | 12 |  |  | 2005-12-01 | 2005-12-01 | 0d | 15d |  |  | 共通 |
| 3 | 3 | 試験完了 | milestone | 0d | 2005-12-15 | 2005-12-15 | 33 |  |  | 2005-12-15 | 2005-12-15 | 0d | 5d |  |  | 共通 |
| 4 | 4 | マニュアル完成 | milestone | 0d | 2005-12-08 | 2005-12-08 | 41 |  |  | 2005-12-08 | 2005-12-08 | 0d | 10d |  |  | 共通 |
| 5 | 5 | 導入完了 | milestone | 0d | 2005-12-22 | 2005-12-22 | 45 |  |  | 2005-12-22 | 2005-12-22 | 0d | 0d |  | 2005-12-23 | 共通 |
| 6 | 6 | **設計** |  | 18d | 2005-10-03 A | 2005-10-27 A |  | 100% |  | 2005-10-03 | 2005-10-27 | 18d |  |  |  | 共通 |
| 7 | 6.1 | 機能要件の確認 |  | 2d | 2005-10-03 A | 2005-10-04 A |  | 100% |  | 2005-10-03 | 2005-10-04 | 2d |  |  |  | 共通 |
| 8 | 6.2 | 詳細設計 |  | 12d | 2005-10-05 A | 2005-10-21 A | 7 | 100% |  | 2005-10-05 | 2005-10-21 | 12d |  |  |  | 共通 |
| 9 | 6.3 | 詳細設計書作成 |  | 7d | 2005-10-14 A | 2005-10-24 A | 8SS | 100% |  | 2005-10-14 | 2005-10-24 | 7d |  |  |  | 共通 |
| 10 | 6.4 | 試験項目書作成 |  | 2d | 2005-10-25 A | 2005-10-26 A | 9 | 100% |  | 2005-10-25 | 2005-10-26 | 2d |  |  |  | 共通 |
| 11 | 6.5 | 取引先レビュー |  | 1d | 2005-10-27 A | 2005-10-27 A | 10 | 100% |  | 2005-10-27 | 2005-10-27 | 1d |  |  |  | 共通 |
| 12 | 7 | **開発** |  | 23d | 2005-10-28 A | 2005-12-01 | 6 | 66% | 7.79d | 2005-10-28 | 2005-12-01 | 23d | 0d |  |  | 共通 |
| 13 | 7.1 | 開発環境構築 |  | 2d | 2005-10-28 A | 2005-10-31 A |  | 100% |  | 2005-10-28 | 2005-10-31 | 2d |  |  |  | 共通 |
| 14 | 7.2 | **プログラミング** |  | 21d | 2005-11-01 A | 2005-12-01 | 13 | 65% | 7.35d | 2005-11-01 | 2005-12-01 | 21d | 0d |  |  | 共通 |
| 15 | 7.2.1 | **機能A** |  | 18d | 2005-11-01 A | 2005-11-28 |  | 72% | 5d | 2005-11-01 | 2005-12-01 | 21d | 3d |  |  | 第１課 |
| 16 | 7.2.1.1 | コーディング |  | 10d | 2005-11-01 A | 2005-11-15 A |  | 100% |  | 2005-11-01 | 2005-11-21 | 14d |  |  |  | 第１課 |
| 17 | 7.2.1.2 | レビュー |  | 1d | 2005-11-16 A | 2005-11-16 A | 16 | 100% |  | 2005-11-22 | 2005-11-22 | 1d |  |  |  | 第１課 |
| 18 | 7.2.1.3 | 修正 |  | 2d | 2005-11-17 A | 2005-11-18 A | 17 | 100% |  | 2005-11-24 | 2005-11-25 | 2d |  |  |  | 第１課 |
| 19 | 7.2.1.4 | 試験ツール作成 |  | 1d | 2005-11-21 | 2005-11-21 | 18 |  |  |  |  |  | 3d | 0d |  | 第１課 |
| 20 | 7.2.1.5 | 単体試験 |  | 4d | 2005-11-22 | 2005-11-28 | 19 |  |  | 2005-11-28 | 2005-12-01 | 4d | 3d |  |  | 第１課 |
| 21 | 7.2.2 | **機能B** |  | 21d | 2005-11-01 A | 2005-12-01 |  | 62% | 8d | 2005-11-01 | 2005-12-01 | 21d | 0d |  |  | 第２課 |
| 22 | 7.2.2.1 | コーディング |  | 13d | 2005-11-01 A | 2005-11-18 A |  | 100% |  | 2005-11-01 | 2005-11-21 | 14d |  |  |  | 第２課 |
| 23 | 7.2.2.2 | レビュー |  | 1d | 2005-11-21 | 2005-11-21 | 22 |  |  | 2005-11-22 | 2005-11-22 | 1d | 0d |  |  | 第２課 |
| 24 | 7.2.2.3 | 修正 |  | 2d | 2005-11-22 | 2005-11-24 | 23 |  |  | 2005-11-24 | 2005-11-25 | 2d | 0d |  |  | 第２課 |
| 25 | 7.2.2.4 | 試験ツール作成 |  | 1d | 2005-11-25 | 2005-11-25 | 24 |  |  |  |  |  | 0d |  |  | 第２課 |
| 26 | 7.2.2.5 | 単体試験 |  | 4d | 2005-11-28 | 2005-12-01 | 25 |  |  | 2005-11-28 | 2005-12-01 | 4d | 0d |  |  | 第２課 |

Notes:
- 12: 関連情報 / http://www.microsoft.com/japan/msdn/library

| ID | WBS | Task | Duration | Start | Finish | Predecessors | Complete | Remaining | Baseline start | Baseline finish | Baseline duration | Total slack | Free slack | Text1 |
| --- | --- | --- | --- | --- | --- | --- | --- | --- | --- | --- | --- | --- | --- | --- |
| 27 | 7.2.3 | **機能C** | 21d | 2005-11-01 A | 2005-12-01 |  | 62% | 8d | 2005-11-01 | 2005-12-01 | 21d | 0d |  | 第３課 |
| 28 | 7.2.3.1 | コーディング | 13d | 2005-11-01 A | 2005-11-18 A |  | 100% |  | 2005-11-01 | 2005-11-21 | 14d |  |  | 第３課 |
| 29 | 7.2.3.2 | レビュー | 1d | 2005-11-21 | 2005-11-21 | 28 |  |  | 2005-11-22 | 2005-11-22 | 1d | 0d |  | 第３課 |
| 30 | 7.2.3.3 | 修正 | 2d | 2005-11-22 | 2005-11-24 | 29 |  |  | 2005-11-24 | 2005-11-25 | 2d | 0d |  | 第３課 |
| 31 | 7.2.3.4 | 試験ツール作成 | 1d | 2005-11-25 | 2005-11-25 | 30 |  |  |  |  |  | 0d |  | 第３課 |
| 32 | 7.2.3.5 | 単体試験 | 4d | 2005-11-28 | 2005-12-01 | 31 |  |  | 2005-11-28 | 2005-12-01 | 4d | 0d |  | 第３課 |
| 33 | 8 | **試験** | 10d | 2005-12-02 | 2005-12-15 | 12 |  |  | 2005-12-02 | 2005-12-15 | 10d | 0d |  | 共通 |
| 34 | 8.1 | 試験環境構築 | 2d | 2005-12-02 | 2005-12-05 |  |  |  | 2005-12-02 | 2005-12-05 | 2d | 0d |  | 共通 |
| 35 | 8.2 | **結合試験** | 5d | 2005-12-06 | 2005-12-12 | 34 |  |  | 2005-12-06 | 2005-12-12 | 5d | 0d |  | 共通 |
| 36 | 8.2.1 | 結合試験実施 | 4d | 2005-12-06 | 2005-12-09 |  |  |  | 2005-12-06 | 2005-12-09 | 4d | 0d |  | 共通 |
| 37 | 8.2.2 | 結合試験成績書作成 | 1d | 2005-12-12 | 2005-12-12 | 36 |  |  | 2005-12-12 | 2005-12-12 | 1d | 0d |  | 共通 |
| 38 | 8.3 | **システム試験** | 3d | 2005-12-13 | 2005-12-15 | 35 |  |  | 2005-12-13 | 2005-12-15 | 3d | 0d |  | 共通 |
| 39 | 8.3.1 | システム試験実施 | 2d | 2005-12-13 | 2005-12-14 |  |  |  | 2005-12-13 | 2005-12-14 | 2d | 0d |  | 共通 |
| 40 | 8.3.2 | システム試験成績書作成 | 1d | 2005-12-15 | 2005-12-15 | 39 |  |  | 2005-12-15 | 2005-12-15 | 1d | 0d |  | 共通 |
| 41 | 9 | **マニュアル作成** | 5d | 2005-12-02 | 2005-12-08 | 12 |  |  | 2005-12-02 | 2005-12-08 | 5d | 5d | 0d | 共通 |
| 42 | 9.1 | ユーザーマニュアル作成 | 3d | 2005-12-02 | 2005-12-06 |  |  |  | 2005-12-02 | 2005-12-06 | 3d | 5d | 0d | 共通 |
| 43 | 9.2 | レビュー | 1d | 2005-12-07 | 2005-12-07 | 42 |  |  | 2005-12-07 | 2005-12-07 | 1d | 5d | 0d | 共通 |
| 44 | 9.3 | 修正 | 1d | 2005-12-08 | 2005-12-08 | 43 |  |  | 2005-12-08 | 2005-12-08 | 1d | 5d |  | 共通 |
| 45 | 10 | **導入** | 5d | 2005-12-16 | 2005-12-22 | 41, 33 |  |  | 2005-12-16 | 2005-12-22 | 5d | 0d |  | 共通 |
| 46 | 10.1 | カスタマイズ機能の導入 | 1d | 2005-12-16 | 2005-12-16 |  |  |  | 2005-12-16 | 2005-12-16 | 1d | 0d |  | 共通 |
| 47 | 10.2 | 仮運用期間 | 4d | 2005-12-19 | 2005-12-22 | 46 |  |  | 2005-12-19 | 2005-12-22 | 4d | 0d |  | 共通 |
