# 戦略的M&Aの評価

Schedule from MS Project, 2005-07-01 to 2005-10-04.
このテンプレートは、企業が事業成長戦略を決定する際の一般的な活動を戦略的事業開発の観点から扱います。ロードマップには、企業のマーケットポジションの把握、M&Aと社内事業開発との間の得失評価、M&A候補の評価、およびターゲット企業の査定が含まれます。

## Calendars

- Standard: Mon-Fri 08:00-12:00, 13:00-17:00; Sat-Sun off.

## Resources

| Resource | Notes |
| --- | --- |
| 幹部委員会 |  |
| 投資銀行 |  |
| M&Aチーム | M&Aチームは、法務、財務、ヒューマンインパクト、マーケティング、リスク管理、および業界の専門家を代表するメンバーから構成します。 |

## Schedule

| ID | WBS | Task | Type | Duration | Start | Finish | Predecessors | Total slack | Free slack | Resources | Work |
| --- | --- | --- | --- | --- | --- | --- | --- | --- | --- | --- | --- |
| 1 | 1 | **M&A戦略の作成** |  | 10d | 2005-07-01 | 2005-07-14 |  | 0d |  |  | 120h |
| 2 | 1.1 | **現在の能力および位置付けの明確化** |  | 3d | 2005-07-01 | 2005-07-05 |  | 0d |  |  | 24h |
| 3 | 1.1.1 | 競争分析を実施する |  | 1d | 2005-07-01 | 2005-07-01 |  | 0d |  | 幹部委員会 | 8h |
| 4 | 1.1.2 | 市場動向分析を実施する |  | 1d | 2005-07-04 | 2005-07-04 | 3 | 0d |  | 幹部委員会 | 8h |
| 5 | 1.1.3 | 現在の位置付けおよびギャップを定義する |  | 1d | 2005-07-05 | 2005-07-05 | 4 | 0d |  | 幹部委員会 | 8h |
| 6 | 1.1.4 | 現在の位置付け分析完了 | milestone | 0d | 2005-07-05 | 2005-07-05 | 5 | 0d |  |  |  |
| 7 | 1.2 | **M&Aの目標の定義** |  | 4d | 2005-07-06 | 2005-07-11 |  | 0d |  |  | 32h |
| 8 | 1.2.1 | M&Aの戦略的目標を定義する |  | 1d | 2005-07-06 | 2005-07-06 | 6 | 0d |  | 幹部委員会 | 8h |
| 9 | 1.2.2 | **M&Aに関するリスク許容度を定義する** |  | 3d | 2005-07-07 | 2005-07-11 |  | 9d |  |  | 24h |
| 10 | 1.2.2.1 | 財務リスクの許容度を定義する |  | 1d | 2005-07-07 | 2005-07-07 | 8 | 9d | 0d | 幹部委員会 | 8h |
| 11 | 1.2.2.2 | マーケットポジションのリスクの許容度を定義する |  | 1d | 2005-07-08 | 2005-07-08 | 10 | 9d | 0d | 幹部委員会 | 8h |
| 12 | 1.2.2.3 | 能力リスクの許容度を定義する |  | 1d | 2005-07-11 | 2005-07-11 | 11 | 9d | 0d | 幹部委員会 | 8h |
| 13 | 1.2.2.4 | リスク許容度評価完了 | milestone | 0d | 2005-07-11 | 2005-07-11 | 12 | 9d | 0d | 幹部委員会 |  |
| 14 | 1.3 | **社内対M&Aの比較評価基準の定義** |  | 3d | 2005-07-12 | 2005-07-14 |  | 9d |  |  | 24h |
| 15 | 1.3.1 | 社内事業開発能力モデルを定義する |  | 1d | 2005-07-12 | 2005-07-12 | 13 | 9d | 0d | 幹部委員会 | 8h |
| 16 | 1.3.2 | 社内対M&Aの比較モデルを定義する |  | 1d | 2005-07-13 | 2005-07-13 | 15 | 9d | 0d | 幹部委員会 | 8h |
| 17 | 1.3.3 | 選定シナリオおよびターゲットパフォーマンス測定基準を定義する |  | 1d | 2005-07-14 | 2005-07-14 | 16 | 9d | 0d | 幹部委員会 | 8h |
| 18 | 1.3.4 | 社内対M&Aの比較評価基準定義完了 | milestone | 0d | 2005-07-14 | 2005-07-14 | 17 | 9d | 0d | 幹部委員会 |  |
| 19 | 1.4 | **M&Aチームの組織** |  | 5d | 2005-07-07 | 2005-07-13 |  | 0d |  |  | 40h |
| 20 | 1.4.1 | M&Aチームのメンバーを選定する |  | 1d | 2005-07-07 | 2005-07-07 | 8 | 0d |  | 幹部委員会 | 8h |
| 21 | 1.4.2 | M&Aチームの設立綱領を文書化する |  | 1d | 2005-07-08 | 2005-07-08 | 20 | 0d |  | 幹部委員会 | 8h |
| 22 | 1.4.3 | M&Aチームの主要なマイルストーンを設定する |  | 1d | 2005-07-11 | 2005-07-11 | 21 | 0d |  | 幹部委員会 | 8h |
| 23 | 1.4.4 | M&Aチームのプロセスを設定する |  | 1d | 2005-07-12 | 2005-07-12 | 22 | 0d |  | 幹部委員会 | 8h |
| 24 | 1.4.5 | M&Aチームのキックオフ会議を開催する |  | 1d | 2005-07-13 | 2005-07-13 | 23 | 0d |  | 幹部委員会 | 8h |
| 25 | 1.4.6 | M&Aチームの組織完了 | milestone | 0d | 2005-07-13 | 2005-07-13 | 24 | 0d |  |  |  |

| ID | WBS | Task | Type | Duration | Start | Finish | Predecessors | Total slack | Resources | Work |
| --- | --- | --- | --- | --- | --- | --- | --- | --- | --- | --- |
| 26 | 2 | **M&Aターゲットの特定および審査基準の作成** |  | 11d | 2005-07-14 | 2005-07-28 |  | 0d |  | 88h |
| 27 | 2.1 | **ターゲット選定基準の定義** |  | 6d | 2005-07-14 | 2005-07-21 |  | 0d |  | 48h |
| 28 | 2.1.1 | 業界、製品、チャネルの基準を定義する |  | 1d | 2005-07-14 | 2005-07-14 | 19, 25 | 0d | M&Aチーム | 8h |
| 29 | 2.1.2 | 収益性、資本化、キャッシュフローの基準を定義する |  | 1d | 2005-07-15 | 2005-07-15 | 28 | 0d | M&Aチーム | 8h |
| 30 | 2.1.3 | 知的所有権およびR&Dの基準を定義する |  | 1d | 2005-07-18 | 2005-07-18 | 29 | 0d | M&Aチーム | 8h |
| 31 | 2.1.4 | 管理、組織、ガバナンスの基準を定義する |  | 1d | 2005-07-19 | 2005-07-19 | 30 | 0d | M&Aチーム | 8h |
| 32 | 2.1.5 | リスク、法務、財務に関する脅威の基準を定義する |  | 1d | 2005-07-20 | 2005-07-20 | 31 | 0d | M&Aチーム | 8h |
| 33 | 2.1.6 | シナジーの基準を定義し、まとめる |  | 1d | 2005-07-21 | 2005-07-21 | 32 | 0d | M&Aチーム | 8h |
| 34 | 2.1.7 | ターゲット選定基準の定義完了 | milestone | 0d | 2005-07-21 | 2005-07-21 | 33 | 0d |  |  |
| 35 | 2.2 | **量的・質的審査基準の定義** |  | 5d | 2005-07-22 | 2005-07-28 |  | 0d |  | 40h |
| 36 | 2.2.1 | 業界、製品、チャネルの審査基準を定義する |  | 1d | 2005-07-22 | 2005-07-22 | 34 | 0d | M&Aチーム | 8h |
| 37 | 2.2.2 | 収益性、資本化、キャッシュフローの審査基準を定義する |  | 1d | 2005-07-25 | 2005-07-25 | 36 | 0d | M&Aチーム | 8h |
| 38 | 2.2.3 | 知的所有権およびR&Dの審査基準を定義する |  | 1d | 2005-07-26 | 2005-07-26 | 37 | 0d | M&Aチーム | 8h |
| 39 | 2.2.4 | 管理、組織、ガバナンスの基準を定義する |  | 1d | 2005-07-27 | 2005-07-27 | 38 | 0d | M&Aチーム | 8h |
| 40 | 2.2.5 | リスク、法務、財務に関する脅威の基準を定義する |  | 1d | 2005-07-28 | 2005-07-28 | 39 | 0d | M&Aチーム | 8h |
| 41 | 2.2.6 | 審査基準の定義完了 | milestone | 0d | 2005-07-28 | 2005-07-28 | 40 | 0d |  |  |
| 42 | 3 | **買収候補リストの作成** |  | 40d | 2005-07-15 | 2005-09-08 |  | 0d |  | 248h |
| 43 | 3.1 | 投資銀行を選定する |  | 1d | 2005-07-15 | 2005-07-15 | 18 | 9d | M&Aチーム | 8h |
| 44 | 3.2 | 買収候補リストを作成する |  | 6w | 2005-07-29 | 2005-09-08 | 43, 41 | 0d | 投資銀行 | 240h |
| 45 | 3.3 | 買収候補リストの作成完了 | milestone | 0d | 2005-09-08 | 2005-09-08 | 44 | 0d |  |  |
| 46 | 4 | **M&Aターゲット企業価値評価分析およびデューデリジェンスの実施** |  | 11d | 2005-09-09 | 2005-09-23 |  | 0d |  | 200h |
| 47 | 4.1 | **企業価値評価分析を実施する** |  | 3d | 2005-09-09 | 2005-09-13 |  | 0d |  | 136h |
| 48 | 4.1.1 | **財務価値の評価分析を実施する** |  | 3d | 2005-09-09 | 2005-09-13 |  | 0d |  | 24h |
| 49 | 4.1.1.1 | 財務シナリオを定義する |  | 1d | 2005-09-09 | 2005-09-09 | 45 | 0d | M&Aチーム | 8h |
| 50 | 4.1.1.2 | 財務シナジー分析を作成する |  | 1d | 2005-09-12 | 2005-09-12 | 49 | 0d | M&Aチーム | 8h |
| 51 | 4.1.1.3 | 財務面でのリスクおよび機会を定義する |  | 1d | 2005-09-13 | 2005-09-13 | 50 | 0d | M&Aチーム | 8h |

Notes:
- 26: ここでは、候補企業リスト作成のために仲介業者に渡す基準を作成します。
- 50: つまり、先に定義し実現しようとしている戦略に対し、このM&Aが財務的な面で沿っているかどうか。

| ID | WBS | Task | Type | Duration | Start | Finish | Predecessors | Total slack | Free slack | Resources | Work |
| --- | --- | --- | --- | --- | --- | --- | --- | --- | --- | --- | --- |
| 52 | 4.1.2 | **市場分析および製品分析を実施する** |  | 3d | 2005-09-09 | 2005-09-13 |  | 0d |  |  | 24h |
| 53 | 4.1.2.1 | 市場シナジーを明らかにする |  | 1d | 2005-09-09 | 2005-09-09 | 45 | 0d |  | M&Aチーム | 8h |
| 54 | 4.1.2.2 | 製品シナジーを明らかにする |  | 1d | 2005-09-12 | 2005-09-12 | 53 | 0d |  | M&Aチーム | 8h |
| 55 | 4.1.2.3 | ポートフォリオ戦略を明らかにする |  | 1d | 2005-09-13 | 2005-09-13 | 54 | 0d |  | M&Aチーム | 8h |
| 56 | 4.1.3 | 業界固有の分析を実施する |  | 1d | 2005-09-09 | 2005-09-09 | 45 | 2d |  | M&Aチーム | 8h |
| 57 | 4.1.4 | (該当する場合) 知的所有権およびR&Dの分析を実施する |  | 1d | 2005-09-09 | 2005-09-09 | 45 | 2d |  | M&Aチーム | 8h |
| 58 | 4.1.5 | **法律および政府規制に対する適合の分析を実施する** |  | 3d | 2005-09-09 | 2005-09-13 |  | 0d |  |  | 24h |
| 59 | 4.1.5.1 | 法的なリスク、問題、およびシナリオを定義する |  | 1d | 2005-09-09 | 2005-09-09 | 45 | 0d |  | M&Aチーム | 8h |
| 60 | 4.1.5.2 | SEC準拠に関するリスク、問題、およびシナリオを定義する |  | 1d | 2005-09-12 | 2005-09-12 | 59 | 0d |  | M&Aチーム | 8h |
| 61 | 4.1.5.3 | その他の政府規制に関するリスク、問題およびシナリオを定義する |  | 1d | 2005-09-13 | 2005-09-13 | 60 | 0d |  | M&Aチーム | 8h |
| 62 | 4.1.6 | **経営および企業ガバナンスの分析を実施する** |  | 3d | 2005-09-09 | 2005-09-13 |  | 0d |  |  | 24h |
| 63 | 4.1.6.1 | 経営に関するシナジーおよびシナリオを定義する |  | 1d | 2005-09-09 | 2005-09-09 | 45 | 0d |  | M&Aチーム | 8h |
| 64 | 4.1.6.2 | 企業ガバナンスに関するシナジーおよびシナリオを定義する |  | 1d | 2005-09-12 | 2005-09-12 | 63 | 0d |  | M&Aチーム | 8h |
| 65 | 4.1.6.3 | 機関投資家に関するシナジー、影響、およびシナリオを定義する |  | 1d | 2005-09-13 | 2005-09-13 | 64 | 0d |  | M&Aチーム | 8h |
| 66 | 4.1.7 | **適正評価のチェックリストを最終化する** |  | 3d | 2005-09-09 | 2005-09-13 |  | 15d |  |  | 24h |
| 67 | 4.1.7.1 | 適正評価活動に優先順位を付ける |  | 1d | 2005-09-09 | 2005-09-09 | 45 | 15d | 0d | M&Aチーム | 8h |
| 68 | 4.1.7.2 | 適正評価活動を割り当てる |  | 1d | 2005-09-12 | 2005-09-12 | 67 | 15d | 0d | M&Aチーム | 8h |
| 69 | 4.1.7.3 | 適正評価のスケジュールを定義する |  | 1d | 2005-09-13 | 2005-09-13 | 68 | 15d |  | M&Aチーム | 8h |
| 70 | 4.1.8 | 企業価値評価分析完了 | milestone | 0d | 2005-09-13 | 2005-09-13 | 51, 55, 56, 57, 61, 65 | 0d |  |  |  |
| 71 | 4.2 | **デューデリジェンス活動を実施する** |  | 8d | 2005-09-14 | 2005-09-23 |  | 0d |  |  | 64h |
| 72 | 4.2.1 | 財務費用便益分析に関するデューデリジェンスを実施する |  | 1d | 2005-09-14 | 2005-09-14 | 70 | 0d |  | M&Aチーム | 8h |
| 73 | 4.2.2 | 財務報告要件に関するデューデリジェンスを実施する |  | 1d | 2005-09-15 | 2005-09-15 | 72 | 0d |  | M&Aチーム | 8h |
| 74 | 4.2.3 | 市場および製品に関するデューデリジェンスを実施する |  | 1d | 2005-09-16 | 2005-09-16 | 73 | 0d |  | M&Aチーム | 8h |
| 75 | 4.2.4 | 業界固有のデューデリジェンスを実施する |  | 1d | 2005-09-19 | 2005-09-19 | 74 | 0d |  | M&Aチーム | 8h |
| 76 | 4.2.5 | 知的所有権およびR&Dに関するデューデリジェンスを実施する |  | 1d | 2005-09-20 | 2005-09-20 | 75 | 0d |  | M&Aチーム | 8h |
| 77 | 4.2.6 | 法的、リスク、政府規制適合に関するデューデリジェンスを実施する |  | 1d | 2005-09-21 | 2005-09-21 | 76 | 0d |  | M&Aチーム | 8h |
| 78 | 4.2.7 | 経営および企業ガバナンスに関するデューデリジェンスを実施する |  | 1d | 2005-09-22 | 2005-09-22 | 77 | 0d |  | M&Aチーム | 8h |
| 79 | 4.2.8 | デューデリジェンス評価の結果をまとめる |  | 1d | 2005-09-23 | 2005-09-23 | 78 | 0d |  | M&Aチーム | 8h |
| 80 | 4.2.9 | デューデリジェンス評価完了 | milestone | 0d | 2005-09-23 | 2005-09-23 | 79 | 0d |  |  |  |
| 81 | 4.3 | 査定および適正評価完了 | milestone | 0d | 2005-09-23 | 2005-09-23 | 70, 80 | 0d |  |  |  |

Notes:
- 56: たとえば、製造企業の場合: / グローバル/ローカル物流チャネル分析の定義/ サプライチェーンのシナジーおよびリスクの定義など
- 75: 業界固有のデューデリジェンスの例としては、製造および流通能力の分析やその他の業界固有の達成能力関連プロセスなどがあります。

| ID | WBS | Task | Type | Duration | Start | Finish | Predecessors | Total slack | Resources | Work |
| --- | --- | --- | --- | --- | --- | --- | --- | --- | --- | --- |
| 82 | 5 | **選定の実施** |  | 2d | 2005-09-26 | 2005-09-27 |  | 0d |  | 24h |
| 83 | 5.1 | 選定結果を提示する |  | 1d | 2005-09-26 | 2005-09-26 | 81 | 0d | M&Aチーム; 幹部委員会 | 16h |
| 84 | 5.2 | 予備選定を確認する |  | 1d | 2005-09-27 | 2005-09-27 | 83 | 0d | 幹部委員会 | 8h |
| 85 | 5.3 | 予備選定完了 | milestone | 0d | 2005-09-27 | 2005-09-27 | 84 | 0d |  |  |
| 86 | 6 | **投資活動の実施** |  | 5d | 2005-09-28 | 2005-10-04 |  | 0d |  | 40h |
| 87 | 6.1 | M&Aの資金調達戦略を作成する |  | 1d | 2005-09-28 | 2005-09-28 | 85 | 0d | M&Aチーム | 8h |
| 88 | 6.2 | SEC提出書類を作成する |  | 1d | 2005-09-29 | 2005-09-29 | 87 | 0d | M&Aチーム | 8h |
| 89 | 6.3 | 資金調達を確保 |  | 1d | 2005-09-30 | 2005-09-30 | 88 | 0d | M&Aチーム | 8h |
| 90 | 6.4 | 委任投票の準備を行い、投票を開催する |  | 1d | 2005-10-03 | 2005-10-03 | 89 | 0d | M&Aチーム | 8h |
| 91 | 6.5 | 投資活動を最終化する |  | 1d | 2005-10-04 | 2005-10-04 | 90 | 0d | M&Aチーム | 8h |
| 92 | 6.6 | 活動完了 | milestone | 0d | 2005-10-04 | 2005-10-04 | 91 | 0d | 幹部委員会 |  |
| 93 | 7 | M&A完了 | milestone | 0d | 2005-10-04 | 2005-10-04 | 92 | 0d |  |  |
