# SOX準拠とIT技術利用の選択

Schedule from MS Project, 2004-04-06 to 2004-06-16.
SOX (Sarbanes-Oxley) 法404条に準拠するためには、2004年11月15日以降に決算報告を行う企業のほとんどが、内部統制の有効性について外部監査人の 証明を得る必要があります。企業によっては、この期限に間に合うように、基本的な規制条件を満たすために労働集約的な統制を導入したところもあります。このような企業の多くは現在、導入した統制の見直しを行っており、手作業の削減と効率の向上を図るためIT技術の利用を検討しています。このテンプレートでは、このようなプロセスに関わる一般的な活動を扱います。プロジェクトでは、組織が既にSOXに準拠していると想定しています。

## Calendars

- Standard: Mon-Fri 08:00-12:00, 13:00-17:00; Sat-Sun off.

## Resources

| Resource |
| --- |
| 外部監査企業 |
| CFO |
| 経理 |
| IT責任者/マネージャ |
| ITアプリケーションチーム |
| ITネットワーク・インフラチーム |
| 業務責任者/マネージャ |
| SOX準拠チーム |
| 内部監査責任者 |

## Schedule

| ID | WBS | Task | Type | Duration | Start | Finish | Predecessors | Total slack | Resources | Work |
| --- | --- | --- | --- | --- | --- | --- | --- | --- | --- | --- |
| 1 | 1 | **SOX 準拠レビューの準備** |  | 4d | 2004-04-06 | 2004-04-09 |  | 0d |  | 104h |
| 2 | 1.1 | 外部監査企業との打ち合わせを行う |  | 1d | 2004-04-06 | 2004-04-06 |  | 0d | 外部監査企業 | 8h |
| 3 | 1.2 | SOX準拠レビューにおける役割分担を定義する |  | 1d | 2004-04-07 | 2004-04-07 | 2 | 0d | 外部監査企業; 内部監査責任者; CFO | 24h |
| 4 | 1.3 | SOX準拠レビューおよび意思決定プロセスを定義する |  | 1d | 2004-04-07 | 2004-04-07 | 3SS | 0d | 外部監査企業; 内部監査責任者; CFO | 24h |
| 5 | 1.4 | SOX準拠レビューのプロジェクト計画を作成する |  | 1d | 2004-04-08 | 2004-04-08 | 4 | 0d | 外部監査企業; 内部監査責任者; CFO | 24h |
| 6 | 1.5 | キックオフ会議を開催する |  | 1d | 2004-04-09 | 2004-04-09 | 5 | 0d | 外部監査企業; 内部監査責任者; CFO | 24h |
| 7 | 1.6 | SOX準拠レビューの準備完了 | milestone | 0d | 2004-04-09 | 2004-04-09 | 6 | 47.5d |  |  |
| 8 | 2 | **プロジェクトの発足および対象範囲の決定** |  | 4.5d | 2004-04-12 | 2004-04-16 |  | 0d |  | 40h |
| 9 | 2.1 | 対象範囲に含まれるシステムおよびプロセスを明らかにする |  | 0.5d | 2004-04-12 | 2004-04-12 | 4, 6 | 0d | 経理; SOX準拠チーム | 8h |
| 10 | 2.2 | プロジェクト参加者および関係者の連絡網を作成する |  | 1d | 2004-04-12 | 2004-04-13 | 9 | 0d | SOX準拠チーム | 8h |
| 11 | 2.3 | プロジェクト参加者がSOXに関して必要なトレーニングを明らかにする |  | 1d | 2004-04-13 | 2004-04-14 | 10 | 0d | SOX準拠チーム | 8h |
| 12 | 2.4 | プロジェクトの計画、主なマイルストーン、予算、主要参加者を定義する |  | 1d | 2004-04-14 | 2004-04-15 | 11 | 0d | SOX準拠チーム | 8h |
| 13 | 2.5 | シニアマネジメントのためのプロジェクトの進捗報告および体制を定義する |  | 1d | 2004-04-15 | 2004-04-16 | 12 | 0d | SOX準拠チーム | 8h |
| 14 | 2.6 | プロジェクトの発足完了 | milestone | 0d | 2004-04-16 | 2004-04-16 | 13 | 0d |  |  |
| 15 | 3 | **改善機会のレビューおよび発見** |  | 23d | 2004-04-16 | 2004-05-19 |  | 0d |  | 616h |
| 16 | 3.1 | **リスク評価を実施する** |  | 3d | 2004-04-16 | 2004-04-21 |  | 0d |  | 24h |
| 17 | 3.1.1 | リスク要因をレビューし、確認する |  | 1d | 2004-04-16 | 2004-04-19 | 14 | 0d | SOX準拠チーム | 8h |
| 18 | 3.1.2 | リスク要因の確率と影響を検証する |  | 1d | 2004-04-19 | 2004-04-20 | 17 | 0d | SOX準拠チーム | 8h |
| 19 | 3.1.3 | リスク要因の規模および複雑性を見積もり、検証する |  | 1d | 2004-04-20 | 2004-04-21 | 18 | 0d | SOX準拠チーム | 8h |
| 20 | 3.2 | **重要なアカウントおよび内部統制を洗い出す** |  | 1d | 2004-04-21 | 2004-04-22 |  | 0d |  | 8h |
| 21 | 3.2.1 | 開始、記録、処理、および報告における業務処理統制を洗い出し、検証する |  | 1d | 2004-04-21 | 2004-04-22 | 19 | 0d | SOX準拠チーム | 8h |
| 22 | 3.3 | **一般的なIT統制を確認する** |  | 2d | 2004-04-22 | 2004-04-26 |  | 0d |  | 184h |
| 23 | 3.3.1 | セキュリティポリシーおよび手続きをレビューする |  | 1d | 2004-04-22 | 2004-04-23 | 21 | 0d | ITネットワーク・インフラチーム; SOX準拠チーム | 16h |
| 24 | 3.3.2 | **変更管理ポリシーおよび手続きをレビューする** |  | 1d | 2004-04-22 | 2004-04-23 |  | 0d |  | 48h |
| 25 | 3.3.2.1 | バージョン管理/リリース管理手続きをレビューする |  | 1d | 2004-04-22 | 2004-04-23 | 23SS | 0d | ITネットワーク・インフラチーム; SOX準拠チーム; ITアプリケーションチーム | 24h |
| 26 | 3.3.2.2 | ソースコード/文書バージョン管理手続きをレビューする |  | 1d | 2004-04-22 | 2004-04-23 | 23SS | 0d | ITネットワーク・インフラチーム; SOX準拠チーム; ITアプリケーションチーム | 24h |
| 27 | 3.3.3 | 障害回復手続きをレビューする |  | 1d | 2004-04-22 | 2004-04-23 | 23SS | 0d | SOX準拠チーム; ITネットワーク・インフラチーム | 16h |
| 28 | 3.3.4 | バックアップおよび復旧手続きをレビューする |  | 1d | 2004-04-22 | 2004-04-23 | 23SS | 0d | SOX準拠チーム; ITネットワーク・インフラチーム | 16h |
| 29 | 3.3.5 | サービス品質保証契約 (SLA) ポリシーをレビューする |  | 1d | 2004-04-22 | 2004-04-23 | 23SS | 0d | ITネットワーク・インフラチーム; SOX準拠チーム; ITアプリケーションチーム; IT責任者/マネージャ | 32h |
| 30 | 3.3.6 | アプリケーション開発およびコーディング基準/レビュー手続きをレビューする |  | 1d | 2004-04-22 | 2004-04-23 | 23SS | 0d | ITアプリケーションチーム; SOX準拠チーム | 16h |
| 31 | 3.3.7 | テスト実施ポリシーおよび手続きをレビューする |  | 1d | 2004-04-22 | 2004-04-23 | 23SS | 0d | ITアプリケーションチーム; SOX準拠チーム | 16h |
| 32 | 3.3.8 | QA手続きをレビューする |  | 1d | 2004-04-22 | 2004-04-23 | 23SS | 0d | ITアプリケーションチーム; SOX準拠チーム | 16h |
| 33 | 3.3.9 | 改善機会の調査結果をまとめる |  | 1d | 2004-04-23 | 2004-04-26 | 23, 25, 26, 27, 28, 29, 30, 32, 31 | 0d | SOX準拠チーム | 8h |

Notes:
- 2: 議題: / ｷ課題/ ｷ監査のタイミング/ ｷ必要なスケジュールおよび文書
- 6: 議題: / ｷ役割の割り当て/ ｷタイミングの影響検討およびスケジュール作成

| ID | WBS | Task | Type | Duration | Start | Finish | Predecessors | Total slack | Resources | Work |
| --- | --- | --- | --- | --- | --- | --- | --- | --- | --- | --- |
| 34 | 3.4 | **統制の設計を確認する** |  | 3d | 2004-04-26 | 2004-04-29 |  | 0d |  | 64h |
| 35 | 3.4.1 | ポリシーおよび手続きを明らかにする |  | 1d | 2004-04-26 | 2004-04-27 | 33 | 0d | SOX準拠チーム; 経理 | 16h |
| 36 | 3.4.2 | 記述内容およびフローチャートをレビューする |  | 1d | 2004-04-27 | 2004-04-28 | 35 | 0d | SOX準拠チーム; 経理 | 16h |
| 37 | 3.4.3 | システム構成文書をレビューする |  | 1d | 2004-04-27 | 2004-04-28 | 36SS | 0d | SOX準拠チーム [200%]; ITアプリケーションチーム [200%] | 32h |
| 38 | 3.4.4 | 内部統制のチェックポイントおよびプロセスを検証する |  | 1d | 2004-04-28 | 2004-04-29 | 37 | 0d |  |  |
| 39 | 3.5 | **運用有効性を評価する** |  | 3d | 2004-04-29 | 2004-05-04 |  | 0d |  | 56h |
| 40 | 3.5.1 | 労働集約型およびコスト効率の低い内部統制を明らかにし、確認する |  | 1d | 2004-04-29 | 2004-04-30 | 38 | 0d | SOX準拠チーム [12.5%]; 経理 [12.5%]; CFO [12.5%]; IT責任者/マネージャ [12.5%]; 内部監査責任者 [50%] | 8h |
| 41 | 3.5.2 | 効率の悪い項目に優先順位を付ける - 継続コスト/内部統制リスク/コストおよび効率に対する影響 |  | 1d | 2004-04-30 | 2004-05-03 | 40 | 0d | 内部監査責任者; SOX準拠チーム; CFO | 24h |
| 42 | 3.5.3 | 優先順位の付いた改善事項についてコストと労力を見積もる |  | 1d | 2004-05-03 | 2004-05-04 | 41 | 0d | CFO; 内部監査責任者; SOX準拠チーム | 24h |
| 43 | 3.6 | **費用便益分析を最終化する** |  | 11d | 2004-05-04 | 2004-05-19 |  | 0d |  | 280h |
| 44 | 3.6.1 | 改善機会を技術改善プロジェクトにグループ分けする |  | 1d | 2004-05-04 | 2004-05-05 | 42 | 0d | CFO; 内部監査責任者; SOX準拠チーム; IT責任者/マネージャ; 経理 | 40h |
| 45 | 3.6.2 | 費用便益分析を行う |  | 1d | 2004-05-05 | 2004-05-06 | 44 | 0d | CFO; 内部監査責任者; SOX準拠チーム; IT責任者/マネージャ; 経理 | 40h |
| 46 | 3.6.3 | 将来状況のシナリオおよび機会活用を検討する |  | 1d | 2004-05-06 | 2004-05-07 | 45 | 0d | CFO; 内部監査責任者; SOX準拠チーム; IT責任者/マネージャ; 経理 | 40h |
| 47 | 3.6.4 | ギャップを明らかにする |  | 1d | 2004-05-07 | 2004-05-10 | 46 | 0d | CFO; 内部監査責任者; SOX準拠チーム; IT責任者/マネージャ; 経理 | 40h |
| 48 | 3.6.5 | プロジェクトのリスクおよび何もしない場合の影響を明らかにする |  | 5d | 2004-05-10 | 2004-05-17 | 47 | 0d | SOX準拠チーム | 40h |
| 49 | 3.6.6 | 追加的な主要リソースおよび情報ソースを明らかにする |  | 1d | 2004-05-17 | 2004-05-18 | 48 | 0d | CFO; 内部監査責任者; SOX準拠チーム; IT責任者/マネージャ; 経理 | 40h |
| 50 | 3.6.7 | 対象範囲、参加者、労力を検証する |  | 1d | 2004-05-18 | 2004-05-19 | 49 | 0d | CFO; 内部監査責任者; SOX準拠チーム; IT責任者/マネージャ; 経理 | 40h |
| 51 | 3.7 | 改善計画完了 | milestone | 0d | 2004-05-19 | 2004-05-19 | 50 | 20d |  |  |
| 52 | 4 | **統制の設計** |  | 9d | 2004-05-19 | 2004-06-01 |  | 0d |  | 176h |
| 53 | 4.1 | プロジェクトのキックオフ会議を開催する |  | 1d | 2004-05-19 | 2004-05-20 | 50 | 0d | SOX準拠チーム; ITアプリケーションチーム | 16h |
| 54 | 4.2 | 新しいシステムおよび関連内部統制へのクロスリファレンスを設計する |  | 1d | 2004-05-20 | 2004-05-21 | 53 | 0d | ITアプリケーションチーム; SOX準拠チーム | 16h |
| 55 | 4.3 | **導入する技術を洗い出す** |  | 1d | 2004-05-21 | 2004-05-24 |  | 0d |  | 48h |
| 56 | 4.3.1 | データ入力・編集システムを洗い出す |  | 1d | 2004-05-21 | 2004-05-24 | 54 | 0d | ITアプリケーションチーム; SOX準拠チーム | 16h |
| 57 | 4.3.2 | 記録・監視システムを洗い出す |  | 1d | 2004-05-21 | 2004-05-24 | 56SS | 0d | ITアプリケーションチーム; SOX準拠チーム | 16h |
| 58 | 4.3.3 | 分析・報告システムを洗い出す |  | 1d | 2004-05-21 | 2004-05-24 | 56SS | 0d | ITアプリケーションチーム; SOX準拠チーム | 16h |
| 59 | 4.4 | 必要なプロセス変更を設計する |  | 1d | 2004-05-24 | 2004-05-25 | 56, 57, 58 | 0d | ITアプリケーションチーム; SOX準拠チーム | 16h |
| 60 | 4.5 | ポリシー、基準、手続きを作成する |  | 1d | 2004-05-25 | 2004-05-26 | 59 | 0d | ITアプリケーションチーム; SOX準拠チーム | 16h |
| 61 | 4.6 | 必要になる変更を連絡する |  | 1d | 2004-05-26 | 2004-05-27 | 60 | 0d | ITアプリケーションチーム; SOX準拠チーム | 16h |
| 62 | 4.7 | 適切な統制の頻度を特定する |  | 1d | 2004-05-27 | 2004-05-28 | 61 | 0d | ITアプリケーションチーム; SOX準拠チーム | 16h |
| 63 | 4.8 | 設計を最終化する |  | 1d | 2004-05-28 | 2004-05-31 | 62 | 0d | ITアプリケーションチーム; SOX準拠チーム | 16h |
| 64 | 4.9 | 必要な承認を得る (SOX準拠/マネジメント) |  | 1d | 2004-05-31 | 2004-06-01 | 63 | 0d | ITアプリケーションチーム; SOX準拠チーム | 16h |
| 65 | 4.10 | 統制の設計完了 | milestone | 0d | 2004-06-01 | 2004-06-01 | 64 | 0d | ITアプリケーションチーム; SOX準拠チーム |  |

| ID | WBS | Task | Type | Duration | Start | Finish | Predecessors | Total slack | Resources | Work |
| --- | --- | --- | --- | --- | --- | --- | --- | --- | --- | --- |
| 66 | 5 | **開発** |  | 3d | 2004-06-01 | 2004-06-04 |  | 0d |  | 48h |
| 67 | 5.1 | 再設計したシステムや統制を開発/導入する |  | 1d | 2004-06-01 | 2004-06-02 | 65 | 0d | ITアプリケーションチーム; SOX準拠チーム | 16h |
| 68 | 5.2 | 影響を受けるすべてのグループに変更を再連絡する |  | 1d | 2004-06-02 | 2004-06-03 | 67 | 0d | ITアプリケーションチーム; SOX準拠チーム | 16h |
| 69 | 5.3 | 継続または改善した内部統制を検証する |  | 1d | 2004-06-03 | 2004-06-04 | 68 | 0d | ITアプリケーションチーム; SOX準拠チーム | 16h |
| 70 | 5.4 | 開発完了 | milestone | 0d | 2004-06-04 | 2004-06-04 | 69 | 0d |  |  |
| 71 | 6 | **テスト** |  | 4d | 2004-06-04 | 2004-06-10 |  | 0d |  | 32h |
| 72 | 6.1 | 統制の有効性を検証する |  | 1d | 2004-06-04 | 2004-06-07 | 70 | 0d | ITアプリケーションチーム | 8h |
| 73 | 6.2 | テストケース/結果を文書化し、詳細なテスト計画およびテストサマリーを作成する |  | 1d | 2004-06-07 | 2004-06-08 | 72 | 0d | ITアプリケーションチーム | 8h |
| 74 | 6.3 | 実施した改善/矯正活動を検証する |  | 1d | 2004-06-08 | 2004-06-09 | 73 | 0d | ITアプリケーションチーム | 8h |
| 75 | 6.4 | テスト結果を文書化する |  | 1d | 2004-06-09 | 2004-06-10 | 74 | 0d | ITアプリケーションチーム | 8h |
| 76 | 6.5 | テスト完了 | milestone | 0d | 2004-06-10 | 2004-06-10 | 75 | 0d |  |  |
| 77 | 7 | **導入** |  | 4d | 2004-06-10 | 2004-06-16 |  | 0d |  | 112h |
| 78 | 7.1 | 手続きおよび統制関連の文書を更新する |  | 1d | 2004-06-10 | 2004-06-11 | 76 | 0d | ITアプリケーションチーム; ITネットワーク・インフラチーム; 経理 | 24h |
| 79 | 7.2 | システム変更を実施する |  | 1d | 2004-06-11 | 2004-06-14 | 78 | 0d | ITアプリケーションチーム; ITネットワーク・インフラチーム; 経理 | 24h |
| 80 | 7.3 | 結果および改善点を監視する |  | 1d | 2004-06-14 | 2004-06-15 | 79 | 0d | 経理; ITアプリケーションチーム; ITネットワーク・インフラチーム; SOX準拠チーム | 32h |
| 81 | 7.4 | 結果を文書化してまとめ、シニアマネジメントに提出する |  | 1d | 2004-06-15 | 2004-06-16 | 80 | 0d | 経理; ITアプリケーションチーム; ITネットワーク・インフラチーム; SOX準拠チーム | 32h |
| 82 | 7.5 | 導入完了 | milestone | 0d | 2004-06-16 | 2004-06-16 | 81 | 0d |  |  |
