# No Project Title

Schedule from MS Project, 2006-01-02 to 2006-04-06.
Microsoft

## Calendars

- Standard: Mon-Fri 08:00-12:00, 13:00-17:00; Sat-Sun off.

## Resources

| Resource |
| --- |
| プログラムマネージャ |
| RSM |
| ネットワークエンジニア |
| 調達業者 |
| グループプログラムマネージャ |
| シニアマネジメント |
| プロジェクト要請者 |
| プロジェクト要請者/スポンサー |
| プロジェクトスポンサー |
| 現場IT担当者 |
| 施設部門 |
| ケーブル業者 |
| ITマネージャ |
| インストール業者 |

## Schedule

| ID | WBS | Task | Type | Duration | Start | Finish | Predecessors | Total slack | Resources | Work | Text20 | Text21 |
| --- | --- | --- | --- | --- | --- | --- | --- | --- | --- | --- | --- | --- |
| 1 | 1 | **MICROSOFT IT - 無線LAN設置** |  | 68.12d | 2006-01-02 | 2006-04-06 |  | 0d |  | 162.12h |  |  |
| 2 | 1.1 | **プロジェクト発足** |  | 2d | 2006-01-02 | 2006-01-03 |  | 0d |  | 16h | Protected |  |
| 3 | 1.1.1 | プロジェクト要件を定義する | milestone | 0d | 2006-01-02 | 2006-01-02 |  | 0d | プロジェクト要請者/スポンサー |  |  |  |
| 4 | 1.1.2 | プロジェクトをレビューし、承認する |  | 2d | 2006-01-02 | 2006-01-03 | 3 | 0d | シニアマネジメント | 16h | Protected | GPM |
| 5 | 1.1.3 | プログラムマネージャを任命する | milestone | 0d | 2006-01-03 | 2006-01-03 | 4 | 0d | グループプログラムマネージャ |  | Protected | PM |
| 6 | 1.2 | **計画** |  | 8d | 2006-01-04 | 2006-01-13 |  | 0d |  | 9.44h |  |  |
| 7 | 1.2.1 | プロジェクトに関する情報を収集する |  | 5d | 2006-01-04 | 2006-01-10 | 5 | 0d | プログラムマネージャ [10%] | 4h |  |  |
| 8 | 1.2.2 | ネットワークエンジニアを要請し、プロジェクトに配属する |  | 2d | 2006-01-11 | 2006-01-12 | 7 | 0d | プログラムマネージャ [10%] | 1.6h |  |  |
| 9 | 1.2.3 | キックオフ会議を開催する |  | 1d | 2006-01-13 | 2006-01-13 | 7, 8 | 0d | プロジェクトスポンサー [12%]; プログラムマネージャ [12%]; ネットワークエンジニア [12%]; ITマネージャ [12%] | 3.84h |  |  |
| 10 | 1.2.4 | プロジェクトの基本的な枠組み決定 | milestone | 0h | 2006-01-13 | 2006-01-13 | 9 | 0d | プログラムマネージャ |  |  |  |
| 11 | 1.3 | **実施・管理** |  | 48.12d | 2006-01-16 | 2006-03-23 |  | 0d |  | 104.76h |  |  |
| 12 | 1.3.1 | **設計** |  | 17d | 2006-01-16 | 2006-02-07 |  | 0d |  | 17.04h |  |  |
| 13 | 1.3.1.1 | 設計および作業範囲仕様書 (SOW) を作成する |  | 5d | 2006-01-16 | 2006-01-20 | 10 | 0d | ネットワークエンジニア [10%] | 4h |  |  |
| 14 | 1.3.1.2 | **現場調査 (設計検証)** |  | 4d | 2006-01-25 | 2006-01-30 |  | 0d |  | 8h |  |  |
| 15 | 1.3.1.2.1 | 現場調査を行う |  | 2d | 2006-01-25 | 2006-01-26 | 13FS+2d | 0d | 現場IT担当者 [25%] | 4h |  |  |
| 16 | 1.3.1.2.2 | 現場調査の結果を公表する |  | 2d | 2006-01-27 | 2006-01-30 | 15 | 0d | 現場IT担当者 [25%] | 4h |  |  |
| 17 | 1.3.1.3 | 設計を更新してレビューし、承認する |  | 5d | 2006-01-31 | 2006-02-06 | 16 | 0d | ネットワークエンジニア [10%] | 4h |  |  |
| 18 | 1.3.1.4 | 必要機材の一覧表をPMに提出する |  | 1d | 2006-02-07 | 2006-02-07 | 17 | 0d | ネットワークエンジニア [13%] | 1.04h |  |  |
| 19 | 1.3.2 | **ハードウェアの購入** |  | 28.25d | 2006-02-08 | 2006-03-20 |  | 0d |  | 20.64h |  |  |
| 20 | 1.3.2.1 | 業者に見積もりを依頼する |  | 2d | 2006-02-08 | 2006-02-09 | 18 | 0d | プログラムマネージャ [25%] | 4h |  |  |
| 21 | 1.3.2.2 | 業者から見積もりを受け取る |  | 5d | 2006-02-10 | 2006-02-16 | 20 | 0d | プログラムマネージャ [10%] | 4h |  |  |
| 22 | 1.3.2.3 | 業者を選定し、発注する |  | 1d | 2006-02-17 | 2006-02-17 | 21 | 0d | プログラムマネージャ [33%] | 2.64h |  |  |
| 23 | 1.3.2.4 | 機材納入までのリードタイム |  | 20d | 2006-02-20 | 2006-03-17 | 22 | 0d | 調達業者 [5%] | 8h |  |  |
| 24 | 1.3.2.5 | 機材の納入を受けて検査を行い、現場に保管する |  | 0.25d | 2006-03-20 | 2006-03-20 | 23 | 0d | 現場IT担当者 | 2h |  |  |

Notes:
- 7: 無線対応にするフロアのデスク配置、インストール日、連絡先、ケーブル室の詳細、既存の配線の詳細および要件、既存のネットワーク機器の仕様など。
- 9: プロジェクトの範囲、予算、リソース、およびスケジュールに関するプロジェクト計画について、プロジェクトスポンサーを含めたチームメンバー全員の合意を得て計画を承認します。
- 15: ｷ現場調査の期待項目を設定します。/ ｷすべてのフロアプランを用意しておきます。/ ｷ必要な機材がすべて現場に揃っていることを確認します (はしごなど)。

| ID | WBS | Task | Type | Duration | Start | Finish | Predecessors | Total slack | Free slack | Resources | Work |
| --- | --- | --- | --- | --- | --- | --- | --- | --- | --- | --- | --- |
| 25 | 1.3.3 | **配線** |  | 13d | 2006-02-08 | 2006-02-24 |  | 15.25d |  |  | 36.72h |
| 26 | 1.3.3.1 | 業者に見積もりを依頼する |  | 2d | 2006-02-08 | 2006-02-09 | 18 | 15.25d | 0d | プログラムマネージャ [25%] | 4h |
| 27 | 1.3.3.2 | 業者から見積もりを受け取る |  | 5d | 2006-02-10 | 2006-02-16 | 26 | 15.25d | 0d | プログラムマネージャ [10%] | 4h |
| 28 | 1.3.3.3 | 業者を選定し、発注する |  | 1d | 2006-02-17 | 2006-02-17 | 27 | 15.25d | 0d | プログラムマネージャ [33%] | 2.64h |
| 29 | 1.3.3.4 | 施設管理部門に作業日および業者の立ち入りについて許可をもらう |  | 2d | 2006-02-20 | 2006-02-21 | 28 | 15.25d | 0d | プログラムマネージャ [13%] | 2.08h |
| 30 | 1.3.3.5 | 配線作業開始 |  | 3d | 2006-02-22 | 2006-02-24 | 29 | 15.25d | 0d | ケーブル業者 | 24h |
| 31 | 1.3.3.6 | 配線作業完了 | milestone | 0d | 2006-02-24 | 2006-02-24 | 30 | 15.25d |  | ケーブル業者 |  |
| 32 | 1.3.4 | **インストール業者の契約** |  | 8d | 2006-02-08 | 2006-02-17 |  | 20.25d |  |  | 10.64h |
| 33 | 1.3.4.1 | 業者に見積もりを依頼する |  | 2d | 2006-02-08 | 2006-02-09 | 18 | 20.25d | 0d | プログラムマネージャ [25%] | 4h |
| 34 | 1.3.4.2 | 業者から見積もりを受け取る |  | 5d | 2006-02-10 | 2006-02-16 | 33 | 20.25d | 0d | プログラムマネージャ [10%] | 4h |
| 35 | 1.3.4.3 | 業者を選定し、発注する |  | 1d | 2006-02-17 | 2006-02-17 | 34 | 20.25d |  | プログラムマネージャ [33%] | 2.64h |
| 36 | 1.3.5 | **インストール** |  | 5.88d | 2006-03-15 | 2006-03-23 |  | 5d |  |  | 19.72h |
| 37 | 1.3.5.1 | インストール業者とインストールの事前打ち合わせを行う |  | 0.25d | 2006-03-15 | 2006-03-15 | 43SS-1w | 15.62d |  | プログラムマネージャ; ネットワークエンジニア; インストール業者; ITマネージャ | 8h |
| 38 | 1.3.5.2 | 変更管理通知を提出する |  | 1d | 2006-03-15 | 2006-03-16 | 43SS-1w | 13.88d | 0d | ネットワークエンジニア [13%] | 1.04h |
| 39 | 1.3.5.3 | ITマネージャがエンドユーザにインストール日のサービス停止について知らせる |  | 1d | 2006-03-16 | 2006-03-17 | 38 | 13.88d |  | ITマネージャ [13%] | 1.04h |
| 40 | 1.3.5.4 | インストール業者の立ち入りおよび連絡先を手配する |  | 1d | 2006-03-17 | 2006-03-20 | 43SS-3d | 12.88d |  | プログラムマネージャ [13%] | 1.04h |
| 41 | 1.3.5.5 | DHCPスコープをセットアップする |  | 2d | 2006-03-17 | 2006-03-21 | 43SS-3d | 11.88d |  | ネットワークエンジニア [10%] | 1.6h |
| 42 | 1.3.5.6 | **無線ネットワーク機器の設置と設定** |  | 0.75d | 2006-03-22 | 2006-03-22 |  | 0d |  |  | 6h |
| 43 | 1.3.5.6.1 | スイッチング機器をラックに設置し、WLANアクセスポイントを設定する |  | 0.25d | 2006-03-22 | 2006-03-22 | 31FS+2d, 24FS+2d, 35FS+2d | 0d |  | インストール業者 | 2h |
| 44 | 1.3.5.6.2 | 機器の配線と設定を行う |  | 0.25d | 2006-03-22 | 2006-03-22 | 43 | 0d |  | インストール業者 | 2h |
| 45 | 1.3.5.6.3 | 接続を確認する | milestone | 0h | 2006-03-22 | 2006-03-22 | 44 | 0d |  | インストール業者 |  |
| 46 | 1.3.5.6.4 | ポストインストールスクリプトを実行し、RADIUS認証を有効にして、WLANの接続をテストする |  | 0.25d | 2006-03-22 | 2006-03-22 | 45 | 0d |  | インストール業者 | 2h |
| 47 | 1.3.5.6.5 | WLAN稼動可能 | milestone | 0d | 2006-03-22 | 2006-03-22 | 46 | 0d |  | インストール業者 |  |
| 48 | 1.3.5.7 | インストールの完了をITマネージャに知らせる |  | 1h | 2006-03-23 | 2006-03-23 | 47 | 0d |  | プログラムマネージャ | 1h |
| 49 | 1.3.6 | 受け入れ承認 | milestone | 0h | 2006-03-23 | 2006-03-23 | 48 | 0d |  | ITマネージャ; プロジェクトスポンサー |  |

Notes:
- 38: Microsoft社のグローバルネットワーク監視チームに対する通知。特定の日時に当該無線施設のネットワークに変更を加えることを知らせます。通知には対象となる場所と影響を受けるハードウェアが示されます。
- 39: サービス停止がある場合のみ。

| ID | WBS | Task | Type | Duration | Start | Finish | Predecessors | Total slack | Resources | Work |
| --- | --- | --- | --- | --- | --- | --- | --- | --- | --- | --- |
| 50 | 1.4 | **終了** |  | 10d | 2006-03-23 | 2006-04-06 |  | 0d |  | 31.92h |
| 51 | 1.4.1 | IT部門がWLANのサポートを引き受け、監視する |  | 1w | 2006-03-23 | 2006-03-30 | 49 | 5d | ITマネージャ [10%]; ネットワークエンジニア [10%] | 8h |
| 52 | 1.4.2 | 技術文書および図面を更新し、集中管理する |  | 3d | 2006-03-23 | 2006-03-28 | 49 | 7d | ネットワークエンジニア [8%] | 1.92h |
| 53 | 1.4.3 | 会計処理を行う (請求書の提出と支払い) |  | 2w | 2006-03-23 | 2006-04-06 | 49 | 0d | プログラムマネージャ [10%] | 8h |
| 54 | 1.4.4 | ハードウェアおよび修理メンテナンス契約があれば更新する |  | 1d | 2006-03-23 | 2006-03-24 | 49 | 9d | プログラムマネージャ [25%] | 2h |
| 55 | 1.4.5 | 古い機器の引き取り/破棄を手配する |  | 2d | 2006-03-23 | 2006-03-27 | 49 | 8d | プログラムマネージャ [25%] | 4h |
| 56 | 1.4.6 | プロジェクトチームとともにプロジェクト終了レビューを作成し、承認する |  | 2w | 2006-03-23 | 2006-04-06 | 49 | 0d | プログラムマネージャ [10%] | 8h |
| 57 | 1.4.7 | プロジェクト完了 | milestone | 0h | 2006-04-06 | 2006-04-06 | 56 | 0d | プログラムマネージャ |  |
