# 財務会計システム導入

Schedule from MS Project, 2004-04-06 to 2004-07-15.
このテンプレートは、財務会計システムを導入するための大まかな手順を示します。既存のシステムが既にあり、それを新しいシステムで置き換える場合を想定しています。また、新しく導入するシステムが既に選定されていることも前提になっています。

## Calendars

- Standard: Mon-Fri 08:00-12:00, 13:00-17:00; Sat-Sun off.

## Resources

| Resource |
| --- |
| 経営陣 |
| 情報システム |
| 経理 |
| 法務 |
| 購買 |

## Schedule

| ID | WBS | Task | Type | Duration | Start | Finish | Predecessors | Total slack | Free slack | Resources | Work |
| --- | --- | --- | --- | --- | --- | --- | --- | --- | --- | --- | --- |
| 1 | 1 | 新しい財務会計システムが選定される | milestone | 0d | 2004-04-06 | 2004-04-06 |  | 0d |  |  |  |
| 2 | 2 | **導入要件** |  | 18.33d | 2004-04-06 | 2004-04-30 |  | 0d |  |  | 248h |
| 3 | 2.1 | **パッケージアーキテクチャの検証** |  | 5d | 2004-04-06 | 2004-04-12 |  | 0d |  |  | 56h |
| 4 | 2.1.1 | テクニカルアーキテクチャをレビューする |  | 1d | 2004-04-06 | 2004-04-06 | 1 | 0d |  | 情報システム | 8h |
| 5 | 2.1.2 | パッケージ導入環境を明らかにする |  | 1d | 2004-04-07 | 2004-04-07 | 4 | 0d |  | 情報システム | 8h |
| 6 | 2.1.3 | 初期トレーニングを実施する |  | 1d | 2004-04-07 | 2004-04-07 | 4 | 70.83d |  | 情報システム | 8h |
| 7 | 2.1.4 | パッケージをインストールする |  | 1d | 2004-04-08 | 2004-04-08 | 5 | 0d |  | 情報システム | 8h |
| 8 | 2.1.5 | 使用量および規模変更の選択肢を見積もる |  | 1d | 2004-04-09 | 2004-04-09 | 7 | 68.83d |  | 情報システム | 8h |
| 9 | 2.1.6 | システムの高可用性が実現できるような設計になっていることを確認する |  | 1d | 2004-04-09 | 2004-04-09 | 7 | 67.83d | 0d | 情報システム | 8h |
| 10 | 2.1.7 | テクニカルアーキテクチャのモデルをレビューし、基本的な枠組みを決定する |  | 1d | 2004-04-12 | 2004-04-12 | 9 | 67.83d | 0d | 情報システム | 8h |
| 11 | 2.1.8 | パッケージアーキテクチャの検証完了 | milestone | 0d | 2004-04-12 | 2004-04-12 | 10 | 67.83d |  |  |  |
| 12 | 2.2 | **パッケージおよび要件のレビュー** |  | 2d | 2004-04-09 | 2004-04-12 |  | 0d |  |  | 32h |
| 13 | 2.2.1 | パッケージ内容を確認する |  | 0.5d | 2004-04-09 | 2004-04-09 | 7 | 0d |  | 経理; 情報システム | 8h |
| 14 | 2.2.2 | ビジネス要件モデルを検証する |  | 0.5d | 2004-04-09 | 2004-04-09 | 13 | 0d |  | 経理; 情報システム | 8h |
| 15 | 2.2.3 | ビジネス要件をパッケージと突き合わせる |  | 0.5d | 2004-04-12 | 2004-04-12 | 14 | 0d |  | 経理; 情報システム | 8h |
| 16 | 2.2.4 | パッケージとのギャップを示した文書を作成し、その解決法を検討する |  | 0.5d | 2004-04-12 | 2004-04-12 | 15 | 0d |  | 経理; 情報システム | 8h |
| 17 | 2.2.5 | パッケージおよび要件のレビュー完了 | milestone | 0d | 2004-04-12 | 2004-04-12 | 16 | 0d |  |  |  |
| 18 | 2.3 | **導入オプション** |  | 5d | 2004-04-13 | 2004-04-19 |  | 0d |  |  | 88h |
| 19 | 2.3.1 | ビジネスプロセスオプションを洗い出す |  | 0.5d | 2004-04-13 | 2004-04-13 | 17 | 0d |  | 経理; 情報システム | 8h |
| 20 | 2.3.2 | データ移行戦略を評価する |  | 1d | 2004-04-13 | 2004-04-14 | 19 | 0d |  | 情報システム | 8h |
| 21 | 2.3.3 | 導入方針を評価する |  | 1d | 2004-04-13 | 2004-04-14 | 19 | 0d |  | 情報システム | 8h |
| 22 | 2.3.4 | システムインターフェースを評価する |  | 1d | 2004-04-13 | 2004-04-14 | 19 | 0d |  | 情報システム | 8h |
| 23 | 2.3.5 | 段階的導入オプションを評価する |  | 1d | 2004-04-13 | 2004-04-14 | 19 | 0d |  | 情報システム | 8h |
| 24 | 2.3.6 | 導入オプションを文書化する |  | 1d | 2004-04-14 | 2004-04-15 | 19, 20, 21, 22, 23 | 0d |  | 情報システム | 8h |
| 25 | 2.3.7 | 導入オプションを選択する |  | 1d | 2004-04-15 | 2004-04-16 | 24 | 0d |  | 情報システム | 8h |
| 26 | 2.3.8 | テスト計画およびユーザ受け入れ承認計画を作成する |  | 0.5d | 2004-04-16 | 2004-04-16 | 25 | 0d |  | 情報システム; 経理 | 8h |
| 27 | 2.3.9 | ビジネスプロセスオプションの推奨文書の承認を受ける |  | 1d | 2004-04-19 | 2004-04-19 | 26 | 0d |  | 経理; 経営陣; 情報システム | 24h |
| 28 | 2.3.10 | 導入オプション完了 | milestone | 0d | 2004-04-19 | 2004-04-19 | 27 | 0d |  |  |  |

| ID | WBS | Task | Type | Duration | Start | Finish | Predecessors | Total slack | Free slack | Resources | Work |
| --- | --- | --- | --- | --- | --- | --- | --- | --- | --- | --- | --- |
| 29 | 2.4 | **パッケージの段階的導入の企画** |  | 5d | 2004-04-20 | 2004-04-26 |  | 0d |  |  | 40h |
| 30 | 2.4.1 | 段階的導入を定義する |  | 1d | 2004-04-20 | 2004-04-20 | 28 | 0d |  | 情報システム | 8h |
| 31 | 2.4.2 | 段階的導入の受け入れ基準を定義する |  | 1d | 2004-04-21 | 2004-04-21 | 30 | 0d |  | 情報システム | 8h |
| 32 | 2.4.3 | トレーニング方針および計画を定義する |  | 1d | 2004-04-22 | 2004-04-22 | 31 | 0d |  | 情報システム | 8h |
| 33 | 2.4.4 | 段階的導入計画をまとめる |  | 1d | 2004-04-23 | 2004-04-23 | 32 | 0d |  | 情報システム | 8h |
| 34 | 2.4.5 | 段階的導入計画をレビューする |  | 1d | 2004-04-26 | 2004-04-26 | 33 | 0d |  | 経理 | 8h |
| 35 | 2.4.6 | 導入計画完了 | milestone | 0d | 2004-04-26 | 2004-04-26 | 34 | 0d |  |  |  |
| 36 | 2.5 | **要件フェーズの最終化** |  | 3.33d | 2004-04-27 | 2004-04-30 |  | 0d |  |  | 32h |
| 37 | 2.5.1 | 要件トレーサビリティマトリックスを作成する |  | 1d | 2004-04-27 | 2004-04-27 | 35 | 0d |  | 情報システム | 8h |
| 38 | 2.5.2 | プロジェクト/成果物の基本的な枠組みを決定する |  | 1d | 2004-04-28 | 2004-04-28 | 37 | 0d |  | 情報システム | 8h |
| 39 | 2.5.3 | 次のフェーズのスケジュールを作成する |  | 1d | 2004-04-29 | 2004-04-29 | 38 | 0d |  | 情報システム | 8h |
| 40 | 2.5.4 | プロジェクト委員会でプロジェクトの状況をレビューする |  | 0.33d | 2004-04-30 | 2004-04-30 | 39 | 0d |  | 情報システム; 経理; 経営陣 | 8h |
| 41 | 2.6 | 要件フェーズ完了 | milestone | 0d | 2004-04-30 | 2004-04-30 | 40 | 0d |  |  |  |
| 42 | 3 | **パッケージ統合の設計** |  | 13d | 2004-04-30 | 2004-05-19 |  | 0d |  |  | 208h |
| 43 | 3.1 | **パッケージ反復計画** |  | 3d | 2004-04-30 | 2004-05-05 |  | 0d |  |  | 32h |
| 44 | 3.1.1 | ユーザおよびチームのトレーニングを実施する |  | 1d | 2004-04-30 | 2004-05-03 | 41 | 0d |  | 情報システム | 8h |
| 45 | 3.1.2 | 反復を定義する |  | 1d | 2004-05-03 | 2004-05-04 | 44 | 0d |  | 情報システム | 8h |
| 46 | 3.1.3 | テスト方針を定義する |  | 1d | 2004-04-30 | 2004-05-03 | 44SS | 1d |  | 情報システム | 8h |
| 47 | 3.1.4 | 反復計画をレビューし、基本的な枠組みを決定する |  | 1d | 2004-05-04 | 2004-05-05 | 46, 45 | 0d |  | 情報システム | 8h |
| 48 | 3.2 | **パッケージ導入のプロトタイプ作成** |  | 3.5d | 2004-05-03 | 2004-05-06 |  | 49d |  |  | 48h |
| 49 | 3.2.1 | シナリオを作成する |  | 1d | 2004-05-03 | 2004-05-04 | 44 | 49d | 0d | 情報システム | 8h |
| 50 | 3.2.2 | パッケージの処理にシナリオを対応させる |  | 1d | 2004-05-03 | 2004-05-04 | 49SS+5% | 52d |  | 情報システム | 8h |
| 51 | 3.2.3 | シナリオの手順を定義する |  | 1d | 2004-05-03 | 2004-05-04 | 49SS+5% | 51.25d | 0d | 情報システム | 8h |
| 52 | 3.2.4 | レポートの仕様を指定し、プロトタイプを作成する |  | 1d | 2004-05-04 | 2004-05-05 | 51SS+7.5% | 51.25d |  | 情報システム | 8h |
| 53 | 3.2.5 | 外部とのインターフェースの仕様を指定する |  | 1d | 2004-05-03 | 2004-05-04 | 49SS+5% | 49d | 0d | 情報システム | 8h |
| 54 | 3.2.6 | パッケージのプロトタイプを作成する |  | 1d | 2004-05-04 | 2004-05-05 | 53 | 49d | 0d | 情報システム | 8h |
| 55 | 3.2.7 | パッケージのプロトタイプを試用し、レビューする |  | 1d | 2004-05-05 | 2004-05-06 | 54 | 49d | 0d |  |  |

Notes:
- 30: 異なる段階で導入を行う分野をそれぞれ担当するチームが複数必要になる場合があります。
- 33: (複数) チームによって作成された計画をまとめます。

| ID | WBS | Task | Type | Duration | Start | Finish | Predecessors | Total slack | Free slack | Resources | Work |
| --- | --- | --- | --- | --- | --- | --- | --- | --- | --- | --- | --- |
| 56 | 3.3 | **パッケージ反復の統合** |  | 1d | 2004-05-06 | 2004-05-07 |  | 49d |  |  | 16h |
| 57 | GRBAPI.PC.04.010 | システムおよび統合テストケースを設計する |  | 0.5d | 2004-05-06 | 2004-05-07 | 55 | 49d | 0d | 情報システム; 経理 | 8h |
| 58 | GRBAPI.PC.04.020 | 将来の反復の範囲を確認する |  | 0.5d | 2004-05-07 | 2004-05-07 | 57 | 49d |  | 情報システム; 経理 | 8h |
| 59 | 3.4 | **データ移行設計** |  | 6d | 2004-05-05 | 2004-05-13 |  | 0d |  |  | 64h |
| 60 | GRBAPI.PC.05.010 | データ入手戦略をレビューする |  | 1d | 2004-05-05 | 2004-05-06 | 47 | 0d |  | 情報システム | 8h |
| 61 | GRBAPI.PC.05.020 | データ移行ソースを定義する |  | 1d | 2004-05-06 | 2004-05-07 | 60 | 0d |  | 情報システム | 8h |
| 62 | GRBAPI.PC.05.030 | データ移行規則およびロジックを定義する |  | 1d | 2004-05-07 | 2004-05-10 | 61 | 0d |  | 情報システム | 8h |
| 63 | GRBAPI.PC.05.040 | データのクリーンアップを実施する |  | 1d | 2004-05-07 | 2004-05-10 | 61 | 48.5d |  | 情報システム | 8h |
| 64 | GRBAPI.PC.05.050 | データ移行処理を設計する |  | 1d | 2004-05-10 | 2004-05-11 | 62, 61 | 47.5d |  | 情報システム | 8h |
| 65 | GRBAPI.PC.05.060 | データ移行手順および管理方法を決定する |  | 1d | 2004-05-10 | 2004-05-11 | 62 | 0d |  | 情報システム | 8h |
| 66 | GRBAPI.PC.05.070 | 変換計画をレビューし、基本的な枠組みを決定する |  | 1d | 2004-05-11 | 2004-05-12 | 65 | 0d |  | 情報システム | 8h |
| 67 | GRBAPI.PC.05.080 | 変換計画の承認を得る |  | 1d | 2004-05-12 | 2004-05-13 | 66 | 0d |  | 情報システム [50%]; 経理 [50%] | 8h |
| 68 | 3.5 | **統合設計フェーズの最終化** |  | 4d | 2004-05-13 | 2004-05-19 |  | 0d |  |  | 48h |
| 69 | GRBAPI.PC.GRSEA.010 | 要件トレーサビリティマトリックスを作成する |  | 1d | 2004-05-13 | 2004-05-14 | 67 | 0d |  | 情報システム | 8h |
| 70 | GRBAPI.PC.GRSEA.020 | プロジェクト/成果物の基本的な枠組みを決定する |  | 1d | 2004-05-14 | 2004-05-17 | 69 | 0d |  | 情報システム | 8h |
| 71 | GRBAPI.PC.GRSEA.030 | 次のフェーズのスケジュールを作成する |  | 1d | 2004-05-17 | 2004-05-18 | 70 | 0d |  | 情報システム [50%]; 経理 [50%] | 8h |
| 72 | GRBAPI.PC.GRSEA.040 | プロジェクト委員会でプロジェクトの状況をレビューする |  | 1d | 2004-05-18 | 2004-05-19 | 71 | 0d |  | 経理; 経営陣; 情報システム | 24h |
| 73 | 3.6 | パッケージ統合設計完了 | milestone | 0d | 2004-05-19 | 2004-05-19 | 72 | 0d |  |  |  |
| 74 | 4 | **パッケージの統合** |  | 24.5d | 2004-05-19 | 2004-06-22 |  | 0d |  |  | 312h |
| 75 | 4.1 | **反復計画を作成する** |  | 3d | 2004-05-19 | 2004-05-24 |  | 0d |  |  | 32h |
| 76 | GRBAPI.PINT.02.010 | テクニカルアーキテクチャを確認する |  | 1d | 2004-05-19 | 2004-05-20 | 73 | 0d |  | 情報システム | 8h |
| 77 | GRBAPI.PINT.02.020 | 反復およびビルドを定義する |  | 1d | 2004-05-20 | 2004-05-21 | 76 | 0d |  | 情報システム | 8h |
| 78 | GRBAPI.PINT.02.030 | テストケースの詳細を詰める |  | 1d | 2004-05-21 | 2004-05-24 | 77 | 0d |  | 経理; 情報システム | 16h |
| 79 | 4.2 | **統合** |  | 4.5d | 2004-05-24 | 2004-05-28 |  | 0d |  |  | 56h |
| 80 | GRBAPI.PINT.03.010 | レポートを構築する |  | 1d | 2004-05-24 | 2004-05-25 | 78 | 0d |  | 情報システム | 8h |
| 81 | GRBAPI.PINT.03.020 | 移行コンポーネントを設計し、構築する |  | 1d | 2004-05-25 | 2004-05-26 | 80 | 0d |  | 情報システム | 8h |
| 82 | GRBAPI.PINT.03.030 | 外部インターフェースを設計し、構築する |  | 1d | 2004-05-26 | 2004-05-27 | 81 | 35.5d |  | 情報システム | 8h |
| 83 | GRBAPI.PINT.03.040 | パフォーマンスを最適化する |  | 1d | 2004-05-26 | 2004-05-27 | 81 | 35.5d |  | 情報システム | 8h |
| 84 | GRBAPI.PINT.03.050 | ユニット/統合テストを完了する |  | 1d | 2004-05-25 | 2004-05-26 | 81SS+5% | 0d |  | 情報システム | 8h |
| 85 | GRBAPI.PINT.03.060 | ビルドをレビューし、基本的な枠組みを作成する |  | 1d | 2004-05-26 | 2004-05-27 | 84 | 0d |  | 情報システム | 8h |
| 86 | GRBAPI.PINT.03.070 | テスト用ビルドを提出する |  | 1d | 2004-05-27 | 2004-05-28 | 85 | 0d |  | 情報システム | 8h |

| ID | WBS | Task | Type | Duration | Start | Finish | Predecessors | Total slack | Resources | Work |
| --- | --- | --- | --- | --- | --- | --- | --- | --- | --- | --- |
| 87 | 4.3 | **システムテストの設計と開発** |  | 2d | 2004-05-28 | 2004-06-01 |  | 0d |  | 32h |
| 88 | GRBAPI.PINT.04.010 | テストスクリプトを定義する |  | 1d | 2004-05-28 | 2004-05-31 | 86 | 0d | 情報システム | 8h |
| 89 | GRBAPI.PINT.04.020 | テストケース/要件範囲をレビューする |  | 1d | 2004-05-31 | 2004-06-01 | 88 | 32d | 情報システム | 8h |
| 90 | GRBAPI.PINT.04.030 | 自動スクリプトを作成する |  | 1d | 2004-05-28 | 2004-05-31 | 88SS | 33d | 情報システム | 8h |
| 91 | GRBAPI.PINT.04.040 | 外部テストデータセットを用意する |  | 1d | 2004-05-31 | 2004-06-01 | 88 | 0d | 情報システム | 8h |
| 92 | 4.4 | **システムテストの実施** |  | 3d | 2004-06-01 | 2004-06-04 |  | 0d |  | 24h |
| 93 | GRBAPI.PINT.05.010 | テストを実施し、結果を記録する |  | 1d | 2004-06-01 | 2004-06-02 | 91 | 0d | 情報システム | 8h |
| 94 | GRBAPI.PINT.05.020 | 予期しない結果について調査する |  | 1d | 2004-06-02 | 2004-06-03 | 93 | 0d | 情報システム | 8h |
| 95 | GRBAPI.PINT.05.030 | テスト変更について見積もり、優先順位付け、スケジュール作成を行う |  | 1d | 2004-06-03 | 2004-06-04 | 94 | 0d | 情報システム | 8h |
| 96 | 4.5 | **反復レビュー** |  | 2d | 2004-06-04 | 2004-06-08 |  | 0d |  | 32h |
| 97 | GRBAPI.PINT.06.010 | 現在の反復についてシステムテストの結果をレビューする |  | 1d | 2004-06-04 | 2004-06-07 | 95 | 0d | 情報システム; 経理 | 16h |
| 98 | GRBAPI.PINT.06.020 | 将来の反復の範囲を確認する |  | 1d | 2004-06-07 | 2004-06-08 | 97 | 0d | 経理; 情報システム | 16h |
| 99 | 4.6 | **承認テスト** |  | 6d | 2004-06-08 | 2004-06-16 |  | 0d |  | 88h |
| 100 | GRBAPI.PINT.07.010 | 承認テストの環境をセットアップする |  | 1d | 2004-06-08 | 2004-06-09 | 98 | 0d | 情報システム | 8h |
| 101 | GRBAPI.PINT.07.020 | 承認テストのスクリプトを作成する |  | 1d | 2004-06-09 | 2004-06-10 | 100 | 0d | 情報システム; 経理 | 16h |
| 102 | GRBAPI.PINT.07.030 | 承認テストを実施し、結果を記録する |  | 1d | 2004-06-10 | 2004-06-11 | 101 | 0d | 情報システム; 経理 | 16h |
| 103 | GRBAPI.PINT.07.040 | 承認テストに基づいてシステムを更新する |  | 1d | 2004-06-11 | 2004-06-14 | 102 | 0d | 情報システム; 経理 | 16h |
| 104 | GRBAPI.PINT.07.050 | 承認テストを再実行し、結果を記録する |  | 1d | 2004-06-14 | 2004-06-15 | 103 | 0d | 情報システム; 経理 | 16h |
| 105 | GRBAPI.PINT.07.060 | システムの承認を得る |  | 1d | 2004-06-15 | 2004-06-16 | 104 | 0d | 情報システム; 経理 | 16h |
| 106 | 4.7 | パッケージの導入完了 | milestone | 0d | 2004-06-16 | 2004-06-16 | 105 | 0d |  |  |
| 107 | 4.8 | **パッケージ統合フェーズの最終化** |  | 4d | 2004-06-16 | 2004-06-22 |  | 0d |  | 48h |
| 108 | GRBAPI.PINT.GRSEA.010 | 要件トレーサビリティマトリックスを作成する |  | 1d | 2004-06-16 | 2004-06-17 | 106 | 0d | 経理; 情報システム | 16h |
| 109 | GRBAPI.PINT.GRSEA.020 | プロジェクト/成果物の基本的な枠組みを決定する |  | 1d | 2004-06-17 | 2004-06-18 | 108 | 0d | 経理; 情報システム | 16h |
| 110 | GRBAPI.PINT.GRSEA.030 | 次のフェーズのスケジュールを作成する |  | 1d | 2004-06-18 | 2004-06-21 | 109 | 0d | 経理; 情報システム | 16h |
| 111 | GRBAPI.PINT.GRSEA.040 | プロジェクト委員会でプロジェクトの状況をレビューする |  | 1d | 2004-06-21 | 2004-06-22 | 110 | 0d |  |  |

| ID | WBS | Task | Type | Duration | Start | Finish | Predecessors | Total slack | Resources | Work |
| --- | --- | --- | --- | --- | --- | --- | --- | --- | --- | --- |
| 112 | 5 | **パッケージの導入** |  | 17d | 2004-06-22 | 2004-07-15 |  | 0d |  | 176h |
| 113 | 5.1 | **教育の企画** |  | 4d | 2004-06-22 | 2004-06-28 |  | 0d |  | 56h |
| 114 | 5.1.1 | トレーニング環境をセットアップする |  | 1d | 2004-06-22 | 2004-06-23 | 111 | 0d | 情報システム | 8h |
| 115 | 5.1.2 | アプリケーションユーザガイドを作成する |  | 1d | 2004-06-23 | 2004-06-24 | 114 | 0d | 情報システム; 経理 | 16h |
| 116 | 5.1.3 | システム管理者ガイドを作成する |  | 1d | 2004-06-24 | 2004-06-25 | 115 | 0d | 情報システム; 経理 | 16h |
| 117 | 5.1.4 | トレーニング教材を作成する |  | 1d | 2004-06-25 | 2004-06-28 | 116 | 0d | 情報システム; 経理 | 16h |
| 118 | 5.2 | **パッケージ導入の準備** |  | 6d | 2004-06-28 | 2004-07-06 |  | 0d |  | 48h |
| 119 | 5.2.1 | バックグラウンドスケジューリングプロセスを作成する |  | 1d | 2004-06-28 | 2004-06-29 | 117 | 0d | 情報システム | 8h |
| 120 | 5.2.2 | 本番用テストスクリプトを作成する |  | 1d | 2004-06-29 | 2004-06-30 | 119 | 0d | 情報システム | 8h |
| 121 | 5.2.3 | 技術導入計画をレビューし、まとめる |  | 1d | 2004-06-30 | 2004-07-01 | 119, 120 | 0d | 情報システム | 8h |
| 122 | 5.2.4 | 技術環境を整備する |  | 1d | 2004-07-01 | 2004-07-02 | 121 | 0d | 情報システム | 8h |
| 123 | 5.2.5 | 導入について説明会を開く |  | 1d | 2004-07-02 | 2004-07-05 | 122 | 0d | 情報システム | 8h |
| 124 | 5.2.6 | トレーニングを実施する |  | 1d | 2004-07-05 | 2004-07-06 | 123 | 7d | 経理 | 8h |
| 125 | 5.2.7 | プロセスのレビューを終える |  | 1d | 2004-07-05 | 2004-07-06 | 123 | 0d |  |  |
| 126 | 5.3 | **インストールおよびハンドオーバー** |  | 5d | 2004-07-06 | 2004-07-13 |  | 0d |  | 40h |
| 127 | 5.3.1 | アプリケーションソフトウェアをインストールする |  | 1d | 2004-07-06 | 2004-07-07 | 125 | 0d | 情報システム | 8h |
| 128 | 5.3.2 | 静的データの変換を行い、新しいデータを入手する |  | 1d | 2004-07-07 | 2004-07-08 | 127 | 0d | 情報システム | 8h |
| 129 | 5.3.3 | 動的データの変換を行う |  | 1d | 2004-07-07 | 2004-07-08 | 127 | 0d | 情報システム | 8h |
| 130 | 5.3.4 | 本番テストを実施する |  | 1d | 2004-07-08 | 2004-07-09 | 128, 129 | 0d | 情報システム | 8h |
| 131 | 5.3.5 | 新しいアプリケーションのカットオーバーを行う |  | 1d | 2004-07-09 | 2004-07-12 | 130 | 0d | 情報システム | 8h |
| 132 | 5.3.6 | メンテナンスガイドを作成する |  | 1d | 2004-07-12 | 2004-07-13 | 131 | 0d |  |  |
| 133 | 5.4 | **導入フェーズの最終化** |  | 2d | 2004-07-13 | 2004-07-15 |  | 0d |  | 32h |
| 134 | 5.4.1 | 反省会を開催する |  | 1d | 2004-07-13 | 2004-07-14 | 132 | 0d | 情報システム; 経理 | 16h |
| 135 | 5.4.2 | プロジェクトファイルを閉める |  | 1d | 2004-07-14 | 2004-07-15 | 134 | 0d | 情報システム; 経理 | 16h |
| 136 | 5.5 | パッケージの導入完了 | milestone | 0d | 2004-07-15 | 2004-07-15 | 135 | 0d |  |  |
| 137 | 6 | プロジェクト完了 | milestone | 0d | 2004-07-15 | 2004-07-15 | 136 | 0d |  |  |
